# ExAOC Construction

Schedule from MS Project, 2019-05-20 to 2024-10-01, status date 2007-12-31, costs in $.
LLNL

## Calendars

- Standard: Mon-Fri 08:00-12:00, 13:00-17:00; Sat-Sun off.

## Resources

| Resource | Rate |
| --- | --- |
| JenkinsD_I | 61.54 |
| CavedoniC_C | 89.53 |
| BoucherL_C | 89.53 |
| AndersenM_P | 79.91 |
| BallJ_P | 65.89 |
| BassettJ_P | 91.13 |
| BlainC_C | 128.52 |
| ChinnB_C | 89.53 |
| MontesV_P | 86.92 |
| CatalaL_C | 56.32 |
| ProvostN_I | 102.57 |
| MontesV_I | 97.83 |
| MorenoC_I | 97.83 |
| SchneiderT_I | 97.83 |
| MorenoC_P | 86.92 |
| BassettJ_C | 93.86 |
| ScharwaechterJ_I | 89.94 |
| MarinE_I | 97.83 |
| ScharwaechterJ_P | 79.91 |
| MarinE_P | 86.92 |
| BallJ_C | 67.87 |
| SivoG_P | 79.91 |
| ProvostN_P | 91.13 |
| PalmerD_P | 124.78 |
| Tech1_P | 66.59 |
| BlankA_C | 40.43 |
| BlainC_P | 124.78 |
| BlankA_P | 39.26 |
| BoucherL_P | 86.92 |
| CatalaL_P | 54.68 |
| SivoG_C | 82.31 |
| EbbersA_C | 81.59 |
| GarciaA_C | 67.87 |
| GoodsellS_C | 128.52 |
| JenkinsD_C | 56.32 |
| KarewiczS_C | 89.53 |
| MontesV_C | 89.53 |
| MorenoC_C | 89.53 |
| KangS_C | 89.53 |
| SchneiderT_C | 89.53 |
| Tech1_C | 68.59 |
| Tech2_C | 68.59 |
| Tech3_C | 68.59 |
| AndersenM_B | 84.78 |
| BallJ_B | 69.91 |
| BassettJ_B | 96.68 |
| KangS_I | 97.83 |
| CavedoniC_P | 86.92 |
| ChinnB_P | 86.92 |
| ChirreE_P | 86.92 |
| EbbersA_P | 79.21 |
| MontesV_B | 92.22 |
| BlainC_B | 132.38 |
| BlankA_B | 41.65 |
| BoucherL_B | 92.22 |
| CatalaL_B | 58.01 |
| ChinnB_B | 92.22 |
| ChirreE_B | 92.22 |
| EbbersA_B | 84.04 |
| CavedoniC_B | 92.22 |
| GoodsellS_B | 132.38 |
| MorenoC_B | 92.22 |
| PalmerD_B | 132.38 |
| ProvostN_B | 96.68 |
| ScharwaechterJ_B | 84.78 |
| SchneiderT_B | 92.22 |
| SivoG_B | 84.78 |
| KarewiczS_I | 97.83 |
| GarciaA_P | 65.89 |
| GoodsellS_P | 124.78 |
| JenkinsD_P | 54.68 |
| KangS_P | 86.92 |
| CatalaL_I | 61.54 |
| Tech1_B | 70.65 |
| Tech2_B | 70.65 |
| Tech3_B | 70.65 |
| AndersenM_I | 89.94 |
| BassettJ_I | 102.57 |
| BlainC_I | 140.44 |
| BlankA_I | 44.18 |
| BallJ_I | 74.16 |
| BoucherL_I | 97.83 |
| CavedoniC_I | 97.83 |
| ChinnB_I | 97.83 |
| ChirreE_I | 97.83 |
| EbbersA_I | 89.15 |
| GarciaA_I | 74.16 |
| GoodsellS_I | 140.44 |
| LombardiG_I | 97.83 |
| JenkinsD_B | 58.01 |
| KangS_B | 92.22 |
| Tech2_P | 66.59 |
| PalmerD_C | 128.52 |
| KarewiczS_B | 92.22 |
| LombardiG_B | 92.22 |
| Tech3_P | 66.59 |
| MarinE_B | 92.22 |
| SchneiderT_P | 86.92 |
| ProvostN_C | 93.86 |
| LombardiG_C | 89.53 |
| AndersenM_C | 82.31 |
| ScharwaechterJ_C | 82.31 |
| GarciaA_B | 69.91 |
| Tech3_I | 74.95 |
| PalmerD_I | 140.44 |
| SivoG_I | 89.94 |
| KarewiczS_P | 86.92 |
| LombardiG_P | 86.92 |
| Tech1_I | 74.95 |
| Tech2_I | 74.95 |
| ChirreE_C | 89.53 |
| MarinE_C | 89.53 |
| HirstP_B | 132.38 |
| HirstP_C | 128.52 |
| HirstP_I | 140.44 |
| HirstP_P | 124.78 |
| RamboldW_B | 96.68 |
| RamboldW_C | 93.86 |
| RamboldW_I | 102.57 |
| RamboldW_P | 91.13 |
| RadwickJ_P | 91.13 |
| SE1_P | 91.13 |
| SW1_P | 79.21 |
| SW2_P | 79.21 |
| RadwickJ_C | 93.86 |
| SE1_C | 93.86 |
| SW1_C | 81.59 |
| SW2_C | 81.59 |
| RadwickJ_B | 96.68 |
| SE1_B | 96.68 |
| SW1_B | 84.04 |
| SW2_B | 84.04 |
| RadwickJ_I | 102.57 |
| SE1_I | 102.57 |
| SW1_I | 89.15 |
| SW2_I | 89.15 |
| LazoM_I | 102.57 |
| LazoM_P | 91.13 |
| LazoM_B | 96.68 |
| LazoM_C | 93.86 |

## Schedule

| ID | WBS | Task | Type | Duration | Start | Finish | Predecessors | Baseline start | Baseline finish | Baseline duration | Total slack | Constraint | Resources | Work | Cost |
| --- | --- | --- | --- | --- | --- | --- | --- | --- | --- | --- | --- | --- | --- | --- | --- |
| 1 | 1 | **GNAO/RTC Project** |  | 280.4w? | 2019-05-20 | 2024-10-01 |  | 2006-06-26 | 2011-01-17 | 1190.47d? | 0d |  |  | 73038.9h | 6,528,377.93 |
| 2 | 1.1 | **Meetings And Milestones** |  | 264.8w? | 2019-09-05 | 2024-10-01 |  | 2006-06-26 | 2011-01-17 | 1190.47d? | 0d |  |  | 1632h | 155,846.4 |
| 3 | 1.1.1 | Submit documentation for CoDR | milestone | 0.2w? | 2019-09-05 | 2019-09-05 | 4FS-2w | 2006-06-26 | 2006-06-27 | 0.4w | 0d |  |  |  |  |
| 4 | 1.1.2 | CoDR |  | 0.4w | 2019-09-17 | 2019-09-18 | 5FS-2w | 2007-05-18 | 2007-05-18 | 0.2w? | 0d |  | AndersenM_P; BlainC_P; BlankA_P; CavedoniC_P; ChinnB_P; ChirreE_P; EbbersA_P; GoodsellS_P; HirstP_P; JenkinsD_P; MarinE_P; MontesV_P; PalmerD_P; ProvostN_P; RamboldW_P; ScharwaechterJ_P; SchneiderT_P | 272h | 24,573.92 |
| 5 | 1.1.3 | CoDR concludes, PD commences | milestone | 0.2w? | 2019-09-30 | 2019-09-30 |  | 2007-05-30 | 2007-05-31 | 0.4w | 0d | start no earlier than 2019-09-30 |  |  |  |
| 6 | 1.1.4 | Submit documentation for PDR | milestone | 0.2w? | 2020-05-06 | 2020-05-06 | 7FS-2w | 2008-05-27 | 2008-05-28 | 0.2w? | 0d |  |  |  |  |
| 7 | 1.1.5 | PDR |  | 0.4w | 2020-05-18 | 2020-05-19 | 8FS-2w | 2008-05-27 | 2008-05-28 | 0.2w? | 0d |  | AndersenM_P; BlainC_P; BlankA_P; CavedoniC_P; ChinnB_P; ChirreE_P; EbbersA_P; GoodsellS_P; HirstP_P; JenkinsD_P; MarinE_P; MontesV_P; PalmerD_P; ProvostN_P; RamboldW_P; ScharwaechterJ_P; SchneiderT_P | 272h | 24,573.92 |
| 8 | 1.1.6 | PDR concludes, CD commences | milestone | 0.2w? | 2020-05-29 | 2020-05-29 |  | 2008-06-06 | 2008-06-10 | 0.4w | 0d | start no earlier than 2020-05-29 |  |  |  |
| 9 | 1.1.7 | Submit documentation for CDR | milestone | 0.2w? | 2021-01-06 | 2021-01-06 | 10FS-2w | 2009-09-18 | 2009-09-21 | 0.2w? | 0d |  |  |  |  |
| 10 | 1.1.8 | CDR |  | 0.4w? | 2021-01-18 | 2021-01-19 | 11FS-2w | 2009-12-29 | 2009-12-31 | 0.4w | 0d |  | AndersenM_C; BlainC_C; BlankA_C; CavedoniC_C; ChinnB_C; ChirreE_C; EbbersA_C; GoodsellS_C; HirstP_C; JenkinsD_C; MarinE_C; MontesV_C; PalmerD_C; ProvostN_C; RamboldW_C; ScharwaechterJ_C; SchneiderT_C | 272h | 25,311.04 |
| 11 | 1.1.9 | CDR concludes, Build commences | milestone | 0.2w? | 2021-01-29 | 2021-01-29 |  | 2009-06-01 | 2009-06-02 | 0.2w? | 0d | start no earlier than 2021-01-29 |  |  |  |
| 12 | 1.1.10 | Submit documents for Pre-I&T Review | milestone | 0.2w? | 2022-09-08 | 2022-09-08 | 13FS-2w | 2009-12-08 | 2009-12-09 | 0.2w? | 0d |  |  |  |  |
| 13 | 1.1.11 | Pre-I&T Review |  | 0.4w? | 2022-09-20 | 2022-09-21 | 14FS-2w | 2010-02-17 | 2010-02-19 | 0.4w | 0d |  | AndersenM_B; BlainC_B; BlankA_B; CavedoniC_B; ChinnB_B; ChirreE_B; EbbersA_B; GoodsellS_B; HirstP_B; JenkinsD_B; MarinE_B; MontesV_B; PalmerD_B; ProvostN_B; RamboldW_B; ScharwaechterJ_B; SchneiderT_B | 272h | 26,071.36 |
| 14 | 1.1.12 | Pre-I&T Review concludes, I&T commences | milestone | 0.2w? | 2022-10-03 | 2022-10-03 |  | 2009-06-30 | 2009-07-01 | 0.2w? | 0d | start no earlier than 2022-10-03 |  |  |  |
| 15 | 1.1.13 | Final document review |  | 0.4w | 2024-03-27 | 2024-03-28 | 16FS-1w | 2010-06-07 | 2010-06-08 | 0.2w? | 0d |  | AndersenM_I; BlainC_I; BlankA_I; CavedoniC_I; ChinnB_I; ChirreE_I; EbbersA_I; GoodsellS_I; HirstP_I; JenkinsD_I; MarinE_I; MontesV_I; PalmerD_I; ProvostN_I; RamboldW_I; ScharwaechterJ_I; SchneiderT_I | 272h | 27,658.08 |
| 16 | 1.1.14 | First Light |  | 0.4w | 2024-04-01 | 2024-04-02 |  | 2011-01-14 | 2011-01-17 | 0.2w? | 0d | start no earlier than 2024-04-01 | AndersenM_I; BlainC_I; BlankA_I; CavedoniC_I; ChinnB_I; ChirreE_I; EbbersA_I; GoodsellS_I; HirstP_I; JenkinsD_I; MarinE_I; MontesV_I; PalmerD_I; ProvostN_I; RamboldW_I; ScharwaechterJ_I; SchneiderT_I | 272h | 27,658.08 |
| 17 | 1.1.15 | Schedule contingency |  | 26w | 2024-04-03 | 2024-10-01 | 16 | 2006-06-26 | 2006-07-17 | 3.2w | 0d |  |  |  |  |
| 19 | 1.2 | **Project Management, including non-subsystem-specific SE** |  | 251.2w | 2019-06-03 | 2024-03-25 |  | 2006-06-28 | 2010-12-31 | 235.49w? | 0d |  |  | 13686.9h | 1,400,896.67 |
| 20 | 1.2.1 | **Project Mannagement (PM), including: project oversight; technical management; schedule, budget, and scope management; procurement and subcontract management; reporting and reviews; and other communications.** |  | 1256d | 2019-06-03 | 2024-03-25 |  |  |  |  | 0d |  |  | 9230h | 982,624 |
| 21 | 1.2.1.1 | **Conceptual Design** |  | 85d | 2019-06-03 | 2019-09-27 |  |  |  |  | 0d |  |  | 850h | 91,524.6 |
| 22 | 1.2.1.1.1 | Project Management |  | 17w | 2019-06-03 | 2019-09-27 |  |  |  |  | 0d |  | PalmerD_P | 680h | 84,850.4 |
| 23 | 1.2.1.1.2 | Project Coordinator |  | 17w | 2019-06-03 | 2019-09-27 |  |  |  |  | 0d |  | BlankA_P [25%] | 170h | 6,674.2 |
| 24 | 1.2.1.2 | **Preliminary Design** |  | 174d | 2019-10-01 | 2020-05-29 | 5 | 2006-06-28 | 2007-05-29 | 48w? | 0d |  |  | 1700h | 183,049.2 |
| 25 | 1.2.1.2.1 | Project Management |  | 34w | 2019-10-01 | 2020-05-25 |  |  |  |  | 0d | start no earlier than 2019-10-01 | PalmerD_P [75%] | 1020h | 127,275.6 |
| 26 | 1.2.1.2.2 | Project Coordinator |  | 34w | 2019-10-01 | 2020-05-25 |  |  |  |  | 0d |  | BlankA_P [25%] | 340h | 13,348.4 |
| 27 | 1.2.1.2.3 | AOS Subcontract Management |  | 34w | 2019-10-07 | 2020-05-29 |  |  |  |  | 0d | finish no earlier than 2020-05-29 | BlainC_P [25%] | 340h | 42,425.2 |

Notes:
- 19: Project Management / System Engineering (LLNL)
- 24: oversee Preliminary Design of telescope and subsystem interfaces, assuring that all interfaces are complete and correct (SE)

| ID | WBS | Task | Duration | Start | Finish | Predecessors | Baseline start | Baseline finish | Baseline duration | Total slack | Resources | Work | Cost |
| --- | --- | --- | --- | --- | --- | --- | --- | --- | --- | --- | --- | --- | --- |
| 28 | 1.2.1.3 | **Critical Design** | 170d | 2020-06-01 | 2021-01-22 | 8 | 2007-06-01 | 2008-04-24 | 46.88w? | 0d |  | 1700h | 188,533.4 |
| 29 | 1.2.1.3.1 | Project Management | 34w | 2020-06-01 | 2021-01-22 |  |  |  |  | 0d | PalmerD_C [75%] | 1020h | 131,090.4 |
| 30 | 1.2.1.3.2 | Project Coordinator | 34w | 2020-06-01 | 2021-01-22 |  |  |  |  | 0d | BlankA_C [25%] | 340h | 13,746.2 |
| 31 | 1.2.1.3.3 | AOS Subcontract Management | 34w | 2020-06-01 | 2021-01-22 |  |  |  |  | 0d | BlainC_C [25%] | 340h | 43,696.8 |
| 32 | 1.2.1.4 | **Build / Implement** | 430d | 2021-02-01 | 2022-09-23 | 11 | 2008-06-10 | 2009-11-17 | 75w? | 0d |  | 3440h | 377,359.4 |
| 33 | 1.2.1.4.1 | Project Management | 86w | 2021-02-01 | 2022-09-23 |  |  |  |  | 0d | PalmerD_B [50%] | 1720h | 227,693.6 |
| 34 | 1.2.1.4.2 | Project Coordinator | 86w | 2021-02-01 | 2022-09-23 |  |  |  |  | 0d | BlankA_B [25%] | 860h | 35,819 |
| 35 | 1.2.1.4.3 | AOS Subcontract Management | 86w | 2021-02-01 | 2022-09-23 |  |  |  |  | 0d | BlainC_B [25%] | 860h | 113,846.8 |
| 36 | 1.2.1.5 | **Integration And Test** | 385d | 2022-10-04 | 2024-03-25 | 14 | 2010-02-19 | 2010-12-31 | 45w? | 0d |  | 1540h | 142,157.4 |
| 37 | 1.2.1.5.1 | Project Management | 77w | 2022-10-04 | 2024-03-25 |  |  |  |  | 0d | PalmerD_I [25%] | 770h | 108,138.8 |
| 38 | 1.2.1.5.2 | Project Coordinator | 77w | 2022-10-04 | 2024-03-25 |  |  |  |  | 0d | BlankA_I [25%] | 770h | 34,018.6 |
| 39 | 1.2.2 | **GNAO/RTC Systems Engineering** | 1256d | 2019-06-03 | 2024-03-25 |  |  |  |  | 0d |  | 4456.89h | 418,272.67 |
| 40 | 1.2.2.1 | **Conceptual Design** | 85d | 2019-06-03 | 2019-09-27 |  |  |  |  | 0d |  | 324.89h | 28,841.67 |
| 41 | 1.2.2.1.1 | Configuration Management | 17w | 2019-06-03 | 2019-09-27 |  |  |  |  | 0d | SE1_P [10%] | 68h | 6,196.84 |
| 42 | 1.2.2.1.2 | Technical team management/coordination | 17w | 2019-06-03 | 2019-09-27 |  |  |  |  | 0d | ProvostN_P [10%] | 68h | 6,196.84 |
| 43 | 1.2.2.1.3 | Risk Management | 17w | 2019-06-03 | 2019-09-27 |  |  |  |  | 0d | ProvostN_P [10%] | 68h | 6,196.84 |
| 44 | 1.2.2.1.4 | Top level systems architecture definitiion and Conceptual Design Iteration | 10w | 2019-06-03 | 2019-08-09 |  |  |  |  | 0d | ProvostN_P [5%]; RamboldW_P [15%]; EbbersA_P [10%] | 20.57h | 1,871.95 |
| 45 | 1.2.2.1.5 | External Interface definition and management | 4w | 2019-08-12 | 2019-09-06 | 44 |  |  |  | 0d | ProvostN_P [20%]; RamboldW_P [20%] | 32.32h | 2,945.32 |
| 46 | 1.2.2.1.6 | Generate and manage error budget | 17w | 2019-06-03 | 2019-09-27 |  |  |  |  | 0d | SivoG_P [10%] | 68h | 5,433.88 |
| 47 | 1.2.2.2 | **Preliminary Design** | 170d | 2019-10-01 | 2020-05-25 | 5 | 2006-06-28 | 2007-05-29 | 48w? | 0d |  | 1088h | 96,002.4 |
| 48 | 1.2.2.2.1 | Configuration Management | 34w | 2019-10-01 | 2020-05-25 |  |  |  |  | 0d | SE1_P [10%] | 136h | 12,393.68 |
| 49 | 1.2.2.2.2 | Technical team management/coordination | 34w | 2019-10-01 | 2020-05-25 |  |  |  |  | 0d | ProvostN_P [10%] | 136h | 12,393.68 |
| 50 | 1.2.2.2.3 | Risk Management | 34w | 2019-10-01 | 2020-05-25 |  |  |  |  | 0d | ProvostN_P [10%] | 136h | 12,393.68 |
| 51 | 1.2.2.2.4 | Top level systems architecture refinement | 34w | 2019-10-01 | 2020-05-25 |  |  |  |  | 0d | ProvostN_P [5%]; RamboldW_P [15%]; EbbersA_P [10%] | 408h | 35,559.92 |
| 52 | 1.2.2.2.5 | External Interface refinement and management | 34w | 2019-10-01 | 2020-05-25 |  |  |  |  | 0d | ProvostN_P [5%]; RamboldW_P [5%] | 136h | 12,393.68 |
| 53 | 1.2.2.2.6 | Refine and manage error budget | 34w | 2019-10-01 | 2020-05-25 |  |  |  |  | 0d | SivoG_P [10%] | 136h | 10,867.76 |

Notes:
- 47: oversee Preliminary Design of telescope and subsystem interfaces, assuring that all interfaces are complete and correct (SE)

| ID | WBS | Task | Duration | Start | Finish | Predecessors | Baseline start | Baseline finish | Baseline duration | Total slack | Resources | Work | Cost |
| --- | --- | --- | --- | --- | --- | --- | --- | --- | --- | --- | --- | --- | --- |
| 54 | 1.2.2.3 | **Critical Design** | 170d | 2020-06-01 | 2021-01-22 | 8 | 2007-06-01 | 2008-04-24 | 46.88w? | 0d |  | 1088h | 98,880.16 |
| 55 | 1.2.2.3.1 | Configuration Management | 34w | 2020-06-01 | 2021-01-22 |  |  |  |  | 0d | SE1_C [10%] | 136h | 12,764.96 |
| 56 | 1.2.2.3.2 | Technical team management/coordination | 34w | 2020-06-01 | 2021-01-22 |  |  |  |  | 0d | ProvostN_C [10%] | 136h | 12,764.96 |
| 57 | 1.2.2.3.3 | Risk Management | 34w | 2020-06-01 | 2021-01-22 |  |  |  |  | 0d | ProvostN_C [10%] | 136h | 12,764.96 |
| 58 | 1.2.2.3.4 | Top level systems architecture refinement | 34w | 2020-06-01 | 2021-01-22 |  |  |  |  | 0d | ProvostN_C [5%]; RamboldW_C [15%]; EbbersA_C [10%] | 408h | 36,626.16 |
| 59 | 1.2.2.3.5 | External Interface refinement and management | 34w | 2020-06-01 | 2021-01-22 |  |  |  |  | 0d | ProvostN_C [5%]; RamboldW_C [5%] | 136h | 12,764.96 |
| 60 | 1.2.2.3.6 | Refine and manage error budget | 34w | 2020-06-01 | 2021-01-22 |  |  |  |  | 0d | SivoG_C [10%] | 136h | 11,194.16 |
| 61 | 1.2.2.4 | **Build / Implement** | 430d | 2021-02-01 | 2022-09-23 | 11 | 2008-06-10 | 2009-11-17 | 75w? | 0d |  | 1032h | 99,773.76 |
| 62 | 1.2.2.4.1 | Configuration Management | 86w | 2021-02-01 | 2022-09-23 |  |  |  |  | 0d | SE1_B [10%] | 344h | 33,257.92 |
| 63 | 1.2.2.4.2 | Technical team management/coordination | 86w | 2021-02-01 | 2022-09-23 |  |  |  |  | 0d | ProvostN_B [10%] | 344h | 33,257.92 |
| 64 | 1.2.2.4.3 | Risk Management | 86w | 2021-02-01 | 2022-09-23 |  |  |  |  | 0d | ProvostN_B [10%] | 344h | 33,257.92 |
| 65 | 1.2.2.5 | **Integration and Test (I&T)** | 385d | 2022-10-04 | 2024-03-25 | 14 | 2010-02-19 | 2010-12-31 | 45w? | 0d |  | 924h | 94,774.68 |
| 66 | 1.2.2.5.1 | Configuration Management | 77w | 2022-10-04 | 2024-03-25 |  |  |  |  | 0d | SE1_I [10%] | 308h | 31,591.56 |
| 67 | 1.2.2.5.2 | Technical team management/coordination | 77w | 2022-10-04 | 2024-03-25 |  |  |  |  | 0d | ProvostN_I [10%] | 308h | 31,591.56 |
| 68 | 1.2.2.5.3 | Risk Management | 77w | 2022-10-04 | 2024-03-25 |  |  |  |  | 0d | ProvostN_I [10%] | 308h | 31,591.56 |
| 70 | 1.3 | **Science, including the AOWG** | 251.2w | 2019-06-03 | 2024-03-25 |  | 2007-06-01 | 2010-12-31 | 935.47d? | 0d |  | 9464h | 764,149.36 |
| 71 | 1.3.1 | **Science** | 865d | 2019-06-03 | 2022-09-23 |  |  |  |  | 0d |  | 4832h | 405,277.2 |
| 72 | 1.3.1.1 | **Conceptual Design** | 85d | 2019-06-03 | 2019-09-27 |  | 2007-06-01 | 2008-03-06 | 40w? | 0d |  | 640h | 51,887.24 |
| 73 | 1.3.1.1.1 | **Prepare science cases and derive scientific requirements** | 85d | 2019-06-03 | 2019-09-27 |  |  |  |  | 0d |  | 100h | 7,991 |
| 74 | 1.3.1.1.1.1 | Collect science case input | 4w | 2019-06-03 | 2019-06-28 |  |  |  |  | 0d | AndersenM_P [10%] | 16h | 1,278.56 |
| 75 | 1.3.1.1.1.2 | Derive science requirements | 4w | 2019-07-01 | 2019-07-26 | 74 |  |  |  | 0d | AndersenM_P [20%] | 32h | 2,557.12 |
| 76 | 1.3.1.1.1.3 | Finalize CoDR version of science case document | 13w | 2019-07-01 | 2019-09-27 | 75FS-4w |  |  |  | 0d | AndersenM_P [10%] | 52h | 4,155.32 |
| 77 | 1.3.1.1.2 | **Prepare Concept of Operations document together with technical team using flowed-down requirements from science team and AO working group. This includes initial strategies for commissioning and acceptance tests. This includes visiting a GeMS run at GS.** | 75d | 2019-06-03 | 2019-09-13 |  |  |  |  | 0d |  | 540h | 43,896.24 |
| 78 | 1.3.1.1.2.1 | Derive LGS concept of operations together with LGS team | 9w | 2019-06-03 | 2019-08-02 |  |  |  |  | 0d | ScharwaechterJ_P [15%]; SivoG_P [5%]; ProvostN_P [5%]; AndersenM_P [5%]; MarinE_P [5%] | 126h | 10,396.8 |
| 79 | 1.3.1.1.2.2 | Derive AO system concept of operations together with AO team | 9w | 2019-06-17 | 2019-08-16 | 78FS-7w |  |  |  | 0d | ScharwaechterJ_P [15%]; SivoG_P [5%]; ProvostN_P [5%]; AndersenM_P [5%]; MontesV_P [5%] | 126h | 10,396.8 |
| 80 | 1.3.1.1.2.3 | Derive software requirements together with software team | 9w | 2019-07-01 | 2019-08-30 | 79FS-7w |  |  |  | 0d | ScharwaechterJ_P [15%]; SivoG_P [5%]; ProvostN_P [5%]; AndersenM_P [5%]; RamboldW_P [5%]; EbbersA_P [5%] | 144h | 11,898.36 |
| 81 | 1.3.1.1.2.4 | Derive science operational concepts together with SOS team | 9w | 2019-07-15 | 2019-09-13 | 80FS-7w |  |  |  | 0d | ScharwaechterJ_P [15%]; SivoG_P [5%]; ProvostN_P [5%]; AndersenM_P [5%]; GarciaA_P [10%] | 144h | 11,204.28 |

| ID | WBS | Task | Duration | Start | Finish | Predecessors | Baseline start | Baseline finish | Baseline duration | Total slack | Resources | Work | Cost |
| --- | --- | --- | --- | --- | --- | --- | --- | --- | --- | --- | --- | --- | --- |
| 82 | 1.3.1.2 | **Preliminary Design** | 175d | 2019-10-01 | 2020-06-01 |  | 2008-06-10 | 2009-11-17 | 75w? | 0d |  | 876h | 70,001.16 |
| 83 | 1.3.1.2.1 | Review/update science cases for PD | 9w | 2020-03-30 | 2020-05-29 | 8FS-9w |  |  |  | 0d | AndersenM_P [10%] | 36h | 2,876.76 |
| 84 | 1.3.1.2.2 | Update concepts of operations for PD | 35w | 2019-10-01 | 2020-06-01 | 5 |  |  |  | 0d | ScharwaechterJ_P [30%] | 420h | 33,562.2 |
| 85 | 1.3.1.2.3 | Participate in preparing acceptance test plan | 35w | 2019-10-01 | 2020-06-01 | 5 |  |  |  | 0d | ScharwaechterJ_P [30%] | 420h | 33,562.2 |
| 86 | 1.3.1.3 | **Critical Design** | 175d | 2020-06-01 | 2021-01-29 |  | 2010-02-19 | 2010-12-31 | 45w? | 0d |  | 1016h | 83,626.96 |
| 87 | 1.3.1.3.1 | Review/update science cases for CD | 9w | 2020-11-30 | 2021-01-29 | 11FS-9w |  |  |  | 0d | AndersenM_C [10%] | 36h | 2,963.16 |
| 88 | 1.3.1.3.2 | Update concepts of operations for CD | 35w | 2020-06-01 | 2021-01-29 | 8 |  |  |  | 0d | ScharwaechterJ_C [20%] | 280h | 23,046.8 |
| 89 | 1.3.1.3.3 | Participate in updating acceptance test plan | 35w | 2020-06-01 | 2021-01-29 | 8 |  |  |  | 0d | ScharwaechterJ_C [20%] | 280h | 23,046.8 |
| 90 | 1.3.1.3.4 | Participate in preparing commissioning plan | 35w | 2020-06-01 | 2021-01-29 | 8 |  |  |  | 0d | ScharwaechterJ_C [30%] | 420h | 34,570.2 |
| 91 | 1.3.1.4 | **Build / Implement** | 430d | 2021-02-01 | 2022-09-23 |  |  |  |  | 0d |  | 1376h | 116,657.28 |
| 92 | 1.3.1.4.1 | Participate in updating acceptance test plan | 86w | 2021-02-01 | 2022-09-23 | 11 |  |  |  | 0d | ScharwaechterJ_B [20%] | 688h | 58,328.64 |
| 93 | 1.3.1.4.2 | Participate in updating commissioning plan | 86w | 2021-02-01 | 2022-09-23 | 11 |  |  |  | 0d | ScharwaechterJ_B [20%] | 688h | 58,328.64 |
| 94 | 1.3.1.5 | **Integration And Test** | 385d | 2019-06-03 | 2020-11-20 |  |  |  |  | 0d |  | 924h | 83,104.56 |
| 95 | 1.3.1.5.1 | Participate in acceptance testing | 77w | 2019-06-03 | 2020-11-20 |  |  |  |  | 0d | ScharwaechterJ_I [30%] | 924h | 83,104.56 |
| 96 | 1.3.2 | **AO Working Group** | 1256d | 2019-06-03 | 2024-03-25 |  |  |  |  | 0d |  | 4632h | 358,872.16 |
| 97 | 1.3.2.1 | **Conceptual Design** | 85d | 2019-06-03 | 2019-09-27 |  |  |  |  | 0d |  | 356h | 24,130.88 |
| 98 | 1.3.2.1.1 | **Define trade off tasks based on science inputs** | 85d | 2019-06-03 | 2019-09-27 |  |  |  |  | 0d |  | 356h | 24,130.88 |
| 99 | 1.3.2.1.1.1 | Review science cases drivers | 4w | 2019-06-03 | 2019-06-28 |  |  |  |  | 0d | SivoG_P [10%] | 16h | 1,278.56 |
| 100 | 1.3.2.1.1.2 | Participate in defining AO trade offs | 4w | 2019-07-01 | 2019-07-26 | 99 |  |  |  | 0d | SivoG_P [20%]; MarinE_P [20%] | 64h | 5,338.56 |
| 101 | 1.3.2.1.1.3 | Participate in performing AO trade offs | 7w | 2019-07-29 | 2019-09-13 | 100 |  |  |  | 0d | SivoG_P [10%] | 28h | 2,237.48 |
| 102 | 1.3.2.1.1.4 | Design and do simulations to support trades and to inform other decisions | 9w | 2019-07-29 | 2019-09-27 | 100 |  |  |  | 0d | SivoG_P [10%]; CatalaL_P [50%] | 216h | 12,719.16 |
| 103 | 1.3.2.1.1.5 | Review/Update GNAO AO documentation | 2w | 2019-09-16 | 2019-09-27 | 101 |  |  |  | 0d | SivoG_P [40%] | 32h | 2,557.12 |
| 104 | 1.3.2.2 | **Preliminary Design** | 170d | 2019-10-01 | 2020-05-25 | 5 |  |  |  | 0d |  | 1088h | 69,785.68 |
| 105 | 1.3.2.2.1 | **Review Concept of Operations document together with technical team using flowed-down requirements from science team and AO working group. This includes initial strategies for commissioning and acceptance tests.** | 170d | 2019-10-01 | 2020-05-25 |  |  |  |  | 0d |  | 1088h | 69,785.68 |
| 106 | 1.3.2.2.1.1 | Review/update AO top-level requirements based on science cases for PDR (including consultation with science team) | 34w | 2019-10-01 | 2020-05-25 |  |  |  |  | 0d | SivoG_P [10%] | 136h | 10,867.76 |
| 107 | 1.3.2.2.1.2 | Detailed AO simulations adapted to selected PD design | 34w | 2019-10-01 | 2020-05-25 |  |  |  |  | 0d | SivoG_P [20%]; CatalaL_P [50%] | 952h | 58,917.92 |

| ID | WBS | Task | Duration | Start | Finish | Predecessors | Baseline start | Baseline finish | Baseline duration | Total slack | Constraint | Resources | Work | Cost |
| --- | --- | --- | --- | --- | --- | --- | --- | --- | --- | --- | --- | --- | --- | --- |
| 108 | 1.3.2.3 | **Critical Design** | 170d | 2020-06-01 | 2021-01-22 | 8 |  |  |  | 0d |  |  | 544h | 44,776.64 |
| 109 | 1.3.2.3.1 | Review/update AO top-level requiremets based on science cases for CDR | 34w | 2020-06-01 | 2021-01-22 |  |  |  |  | 0d |  | SivoG_C [10%] | 136h | 11,194.16 |
| 110 | 1.3.2.3.2 | PI Support | 34w | 2020-06-01 | 2021-01-22 |  |  |  |  | 0d |  | SivoG_C [30%] | 408h | 33,582.48 |
| 111 | 1.3.2.4 | **Build / Implement** | 430d | 2021-02-01 | 2022-09-23 | 11 |  |  |  | 0d |  |  | 1720h | 145,821.6 |
| 112 | 1.3.2.4.1 | PI Support | 86w | 2021-02-01 | 2022-09-23 |  |  |  |  | 0d |  | SivoG_B [50%] | 1720h | 145,821.6 |
| 113 | 1.3.2.5 | **Integration and Test (I&T)** | 385d | 2022-10-04 | 2024-03-25 | 14 |  |  |  | 0d |  |  | 924h | 74,357.36 |
| 114 | 1.3.2.5.1 | Participate in bench performance verification | 77w | 2022-10-04 | 2024-03-25 |  |  |  |  | 0d |  | SivoG_I [20%]; CatalaL_I [10%] | 924h | 74,357.36 |
| 116 | 1.4 | **Laser Guide Star Subsystem (LGS)** | 1250d | 2019-06-03 | 2024-03-15 |  | 2006-06-26 | 2010-12-28 | 235.2w? | 0d |  |  | 26688.2h | 2,330,311.33 |
| 117 | 1.4.1 | **LGS Systems Engineering** | 1246d | 2019-06-03 | 2024-03-11 |  |  |  |  | 0d |  |  | 8396.86h | 768,428.62 |
| 118 | 1.4.1.1 | **Conceptual Design** | 86d | 2019-06-03 | 2019-09-30 |  |  |  |  | 0d |  |  | 1704.86h | 149,480.06 |
| 119 | 1.4.1.1.1 | **LGS Subsystem requirements definition** | 86d | 2019-06-03 | 2019-09-30 |  |  |  |  | 0d |  |  | 420.93h | 38,016.96 |
| 120 | 1.4.1.1.1.1 | Generate LGS Top Level Functional Flow Break Down | 6.25w | 2019-06-03 | 2019-07-16 |  |  |  |  | 0d | start no earlier than 2019-06-03 | BassettJ_P [20%]; RamboldW_P [10%]; MarinE_P [5%]; MorenoC_P [5%] | 83.33h | 7,488.92 |
| 121 | 1.4.1.1.1.2 | Flow Top Level Requirements to LGS from top level science Requirements (First Draft) | 4.5w | 2019-06-03 | 2019-07-03 |  |  |  |  | 0d | start no earlier than 2019-06-03 | BassettJ_P [20%]; RamboldW_P [10%]; MarinE_P [5%]; MorenoC_P [5%] | 60h | 5,392.02 |
| 122 | 1.4.1.1.1.3 | Generate LGS Functional Requirements and compare against existing GN and GS LGS requirements (First Draft) | 1.6w | 2019-06-03 | 2019-06-12 |  |  |  |  | 0d | start no earlier than 2019-06-03 | BassettJ_P [20%]; RamboldW_P [10%]; MarinE_P [5%] | 16h | 1,444.61 |
| 123 | 1.4.1.1.1.4 | Update Requirements based on Interface Definition, Conops, Trade Study Results etc, Add rationale | 8w | 2019-06-03 | 2019-07-26 |  |  |  |  | 0d | start no earlier than 2019-06-03 | BassettJ_P [15%] | 48h | 4,374.24 |
| 124 | 1.4.1.1.1.5 | Generate LGS Verification Plan for each Requirement and fill out VCRM | 12w | 2019-06-10 | 2019-08-30 |  |  |  |  | 0d | finish no earlier than 2019-08-30 | BassettJ_P [20%]; RamboldW_P [10%]; MarinE_P [10%] | 153.6h | 13,849.38 |
| 125 | 1.4.1.1.1.6 | Input LGS Requirements and Verification Methods into DOORS | 11w | 2019-06-17 | 2019-08-30 |  |  |  |  | 0d | finish no earlier than 2019-08-30 | BassettJ_P [10%] | 44h | 4,009.72 |
| 126 | 1.4.1.1.1.7 | Finalize Export LGS Subsystem Requirements Document with VCRM for CoDR | 4w | 2019-09-03 | 2019-09-30 |  |  |  |  | 0d | finish no earlier than 2019-09-30 | BassettJ_P [10%] | 16h | 1,458.08 |
| 127 | 1.4.1.1.2 | **Generate LGS Interface requirements definition** | 86d | 2019-06-03 | 2019-09-30 |  |  |  |  | 0d |  |  | 655.5h | 56,981.14 |
| 128 | 1.4.1.1.2.1 | Define LGSF Functional External Interfaces | 3.48w | 2019-06-03 | 2019-06-26 |  |  |  |  | 0d | start no earlier than 2019-06-03 | ProvostN_P [10%]; BassettJ_P [10%]; RamboldW_P [10%]; MarinE_P [10%]; MorenoC_P [5%]; CavedoniC_P [10%]; KarewiczS_P [10%]; EbbersA_P [10%] | 97.5h | 8,543.23 |
| 129 | 1.4.1.1.2.2 | Generate LGS Interface Control Document for LGS - RTC First Draft | 4w | 2019-06-17 | 2019-07-13 |  |  |  |  | 0d | finish no earlier than 2019-07-13 | ProvostN_P [5%]; RamboldW_P [20%]; EbbersA_P [20%] | 72h | 6,179.92 |
| 130 | 1.4.1.1.2.3 | Generate LGS Interface Control Document for LGS - TLC First Draft | 4w | 2019-06-10 | 2019-07-05 |  |  |  |  | 0d | finish no earlier than 2019-07-05 | ProvostN_P [5%]; RamboldW_P [20%]; EbbersA_P [20%] | 72h | 6,179.92 |
| 131 | 1.4.1.1.2.4 | Generate LGS Interface Control Document for LGS -TCC First Draft | 4w | 2019-06-10 | 2019-07-05 |  |  |  |  | 0d | finish no earlier than 2019-07-05 | ProvostN_P [5%]; RamboldW_P [20%]; EbbersA_P [20%] | 72h | 6,179.92 |
| 132 | 1.4.1.1.2.5 | Update, Review Electrical Interface Requirements | 4w | 2019-07-01 | 2019-07-26 |  |  |  |  | 0d | finish no earlier than 2019-07-26 | ProvostN_P [5%]; MarinE_P [5%]; KarewiczS_P [10%] | 32h | 2,815.12 |
| 133 | 1.4.1.1.2.6 | Update, Review Mechancial Interface Requirements | 4w | 2019-07-01 | 2019-07-26 |  |  |  |  | 0d | finish no earlier than 2019-07-26 | ProvostN_P [5%]; MarinE_P [5%]; CavedoniC_P [15%] | 40h | 3,510.48 |
| 134 | 1.4.1.1.2.7 | Update, Review Service Requirements, including plumbing for Laser Heat Exchanger (LHX) | 4w | 2019-07-01 | 2019-07-26 |  |  |  |  | 0d | finish no earlier than 2019-07-26 | ProvostN_P [5%]; MarinE_P [5%]; CavedoniC_P [15%] | 40h | 3,510.48 |
| 135 | 1.4.1.1.2.8 | Update, ReviewEnvironmental Requiremnts | 5.33w | 2019-06-20 | 2019-07-26 |  |  |  |  | 0d | finish no earlier than 2019-07-26 | ProvostN_P [5%]; MarinE_P [5%]; CavedoniC_P [5%] | 32h | 2,826.35 |
| 136 | 1.4.1.1.2.9 | Review, Update, Finalize CoDR Drafts of ICDs | 9w | 2019-07-30 | 2019-09-30 |  |  |  |  | 0d | finish no earlier than 2019-09-30 | ProvostN_P [10%]; RamboldW_P [10%]; MarinE_P [5%]; CavedoniC_P [10%]; KarewiczS_P [10%]; EbbersA_P [10%] | 198h | 17,235.72 |

Notes:
- 116: Opto-Electro-Mechanical (OEM) Superstructure (HIA)

| ID | WBS | Task | Duration | Start | Finish | Predecessors | Total slack | Constraint | Resources | Work | Cost |
| --- | --- | --- | --- | --- | --- | --- | --- | --- | --- | --- | --- |
| 137 | 1.4.1.1.3 | **Generate LGS ConOps** | 45d | 2019-06-03 | 2019-08-02 |  | 0d |  |  | 292.43h | 25,119.24 |
| 138 | 1.4.1.1.3.1 | Describe GeMS LGSF System and Reason for Change | 3.25w | 2019-06-03 | 2019-06-25 |  | 0d | start no earlier than 2019-06-03 | ProvostN_P [5%]; RamboldW_P [10%]; MarinE_P [20%]; MorenoC_P [5%]; EbbersA_P [10%]; ScharwaechterJ_P [5%] | 64.43h | 5,536.68 |
| 139 | 1.4.1.1.3.2 | Describe GNAO LGSF System Operation, including safety system, diagnostics, alignment, etc. (1st Draft) | 6w | 2019-06-06 | 2019-07-17 |  | 0d | finish no earlier than 2019-07-17 | ProvostN_P [5%]; RamboldW_P [10%]; MarinE_P [20%]; MorenoC_P [5%]; EbbersA_P [10%]; ScharwaechterJ_P [5%] | 132h | 11,355.84 |
| 140 | 1.4.1.1.3.3 | Review, Update LGSF Conops, incorporate into GNAO conops | 6w | 2019-06-24 | 2019-08-02 |  | 0d | finish no earlier than 2019-08-02 | ProvostN_P [5%]; RamboldW_P [10%]; MarinE_P [10%]; EbbersA_P [10%]; ScharwaechterJ_P [5%] | 96h | 8,226.72 |
| 141 | 1.4.1.1.4 | Lead and participate in design trades, particularly the # of LLTs, lasers, and configuration | 16w | 2019-06-03 | 2019-09-20 |  | 0d |  | BassettJ_P [20%]; MarinE_P [20%]; SivoG_P [10%] | 320h | 27,904.64 |
| 142 | 1.4.1.1.5 | Review and provide input on LGS documentation package | 4w | 2019-09-02 | 2019-09-27 |  | 0d | finish no earlier than 2019-09-27 | BassettJ_P [10%] | 16h | 1,458.08 |
| 143 | 1.4.1.2 | **Preliminary and Critical Design** | 345d | 2019-10-01 | 2021-01-25 |  | 0d |  |  | 2412h | 210,741.36 |
| 144 | 1.4.1.2.1 | **LGS Design Systems Engineering and Oversight** | 345d | 2019-10-01 | 2021-01-25 |  | 0d |  |  | 2412h | 210,741.36 |
| 145 | 1.4.1.2.1.1 | Continue to Refine Functional Analysis, LGS Requirements, andConops | 8w | 2019-10-01 | 2019-11-25 | 5 | 0d | start no earlier than 2019-06-03 | MarinE_P [50%]; CavedoniC_P [10%]; EbbersA_P [10%]; SchneiderT_P [10%]; BassettJ_P [20%] | 320h | 27,837.12 |
| 146 | 1.4.1.2.1.2 | Define the Physical Architecture (or Product Breakedown Structure) of LGS, by decomposition of the Functional Architecture, defined from Functional Analysis and Allocation, and LGS decomposition processes. | 8w | 2019-11-26 | 2020-01-20 | 145 | 0d | start no earlier than 2019-06-03 | MarinE_P [50%]; CavedoniC_P [10%]; EbbersA_P [10%]; SchneiderT_P [10%]; BassettJ_P [20%] | 320h | 27,837.12 |
| 147 | 1.4.1.2.1.3 | Define Design Solution of the Physical Architecture that satisfy the ConOps and the de-composed (flowed down, derived and allocated) set of subsystem requirements. | 8w | 2020-01-21 | 2020-03-16 | 146 | 0d | start no earlier than 2019-06-03 | MarinE_P [50%]; CavedoniC_P [10%]; EbbersA_P [10%]; SchneiderT_P [10%]; BassettJ_P [20%] | 320h | 27,837.12 |
| 148 | 1.4.1.2.1.4 | Decompose requirements to component level, generate low level specifications | 8w | 2020-03-17 | 2020-05-11 | 147 | 0d | start no earlier than 2019-06-03 | MarinE_P [50%]; CavedoniC_P [10%]; EbbersA_P [10%]; SchneiderT_P [10%]; BassettJ_P [20%] | 320h | 27,837.12 |
| 149 | 1.4.1.2.1.5 | Manage interfaces and maintain ICDs | 8w | 2020-05-12 | 2020-07-06 | 148 | 0d | start no earlier than 2019-06-03 | MarinE_P [50%]; CavedoniC_P [10%]; EbbersA_P [10%]; SchneiderT_P [10%]; BassettJ_P [20%] | 320h | 27,837.12 |
| 150 | 1.4.1.2.1.6 | Provide SE/WPM oversight | 29w | 2020-07-07 | 2021-01-25 | 149 | 0d |  | BassettJ_P [20%]; MarinE_P [50%] | 812h | 71,555.76 |
| 151 | 1.4.1.3 | **Build and Integration and Testing (I&T)** | 811d | 2021-02-01 | 2024-03-11 | 11 | 0d |  |  | 4280h | 408,207.2 |
| 152 | 1.4.1.3.1 | LGS Fabrication Systems Engineering and Oversight, including change control, interface management, acceptance testing review and oversight, etc. | 86w | 2021-02-01 | 2022-09-23 |  | 0d | finish no earlier than 2022-09-20 | MarinE_B [50%]; BassettJ_B [25%] | 2580h | 241,763.2 |
| 153 | 1.4.1.3.2 | **LGS Verification** | 100d | 2022-10-04 | 2023-02-20 | 14 | 0d |  |  | 600h | 56,224 |
| 154 | 1.4.1.3.2.1 | Generate detailed LGS acceptance plan and procedure | 8w | 2022-10-04 | 2022-11-28 |  | 0d | finish no earlier than 2022-03-01 | MarinE_B [50%]; BassettJ_B [25%] | 240h | 22,489.6 |
| 155 | 1.4.1.3.2.2 | Participate in LGS Acceptance testing, including all verification tests and analyses | 8w | 2022-11-29 | 2023-01-23 | 154 | 0d |  | MarinE_B [50%]; BassettJ_B [25%] | 240h | 22,489.6 |
| 156 | 1.4.1.3.2.3 | Review and approve Acceptance Test results | 4w | 2023-01-24 | 2023-02-20 | 155 | 0d |  | MarinE_B [50%]; BassettJ_B [25%] | 120h | 11,244.8 |
| 157 | 1.4.1.3.3 | Support LGS Integration and Test, including development of integration test plan, implementing plan, lead anomaly resolution, lead interface management, perform tests, review and document results | 55w | 2023-02-21 | 2024-03-11 | 156 | 0d |  | MarinE_I [25%]; BassettJ_I [25%] | 1100h | 110,220 |
| 158 | 1.4.2 | **Conceptual Design** | 86d | 2019-06-03 | 2019-09-30 |  | 0d |  |  | 1436h | 124,200.32 |
| 159 | 1.4.2.1 | **Provide CoD of BTO layout for competing LGSF options. Provide optical performance, pricing difference, and fabrication comparison for consideration. Demonstrate that different designs can meet the project performance requirements.** | 85d | 2019-06-03 | 2019-09-27 |  | 0d |  |  | 304.8h | 26,493.22 |
| 160 | 1.4.2.1.1 | Define functional optical requirements for propsed LGSF options | 17w | 2019-06-03 | 2019-09-27 |  | 0d | start no earlier than 2019-06-03 | SchneiderT_P [5%]; CavedoniC_P [3%] | 54.4h | 4,728.45 |
| 161 | 1.4.2.1.2 | Define functional opto-mechanical requirements for propsed LGSF options | 17w | 2019-06-03 | 2019-09-27 |  | 0d | start no earlier than 2019-06-03 | SchneiderT_P [5%]; CavedoniC_P [3%] | 54.4h | 4,728.45 |
| 162 | 1.4.2.1.3 | Prepare conceptual optical design | 14w | 2019-06-24 | 2019-09-27 |  | 0d | start no earlier than 2019-06-24 | SchneiderT_P [10%] | 56h | 4,867.52 |
| 163 | 1.4.2.1.4 | Prepare conceptual opto-mechanical layout | 14w | 2019-06-24 | 2019-09-27 |  | 0d | start no earlier than 2019-06-24 | SchneiderT_P [10%]; CavedoniC_P [5%] | 84h | 7,301.28 |
| 164 | 1.4.2.1.5 | Prepare cost and scheduld estimates for proposed LGSF options | 14w | 2019-06-24 | 2019-09-27 |  | 0d | start no earlier than 2019-06-24 | SchneiderT_P [10%] | 56h | 4,867.52 |

| ID | WBS | Task | Duration | Start | Finish | Predecessors | Baseline start | Baseline finish | Baseline duration | Total slack | Free slack | Constraint | Resources | Work | Cost |
| --- | --- | --- | --- | --- | --- | --- | --- | --- | --- | --- | --- | --- | --- | --- | --- |
| 165 | 1.4.2.2 | **Prepare MEP (Mechanical, Electrical, and Plumbing) Deliverable for CoD including 3-d mechanical layouts, mechanical balancing plans, mechanical mounting plans, electrical power plans and plumbing service plans.** | 86d | 2019-06-03 | 2019-09-30 |  |  |  |  | 0d |  |  |  | 971.2h | 84,416.7 |
| 166 | 1.4.2.2.1 | Prepare conceptual 3-d layouts for the proposed LGSF option(s) (including necessary LLTs, LHs, ECs, BTOs & LHXs) | 13w | 2019-06-03 | 2019-08-30 |  |  |  |  | 0d |  |  | CavedoniC_P [10%]; KangS_P [50%]; SchneiderT_P [10%] | 364h | 31,638.88 |
| 167 | 1.4.2.2.2 | Prepare conceptual balancing plans for the proposed LGSF option(s) | 13w | 2019-06-03 | 2019-08-30 |  |  |  |  | 0d |  |  | CavedoniC_P [10%] | 52h | 4,519.84 |
| 168 | 1.4.2.2.3 | Prepare conceptual mounting schemes for the proposed LGSF option(s) | 13w | 2019-06-03 | 2019-08-30 |  |  |  |  | 0d |  |  | CavedoniC_P [10%]; KangS_P [50%] | 312h | 27,119.04 |
| 169 | 1.4.2.2.4 | Prepare conceptual plumbing service plans for proposed LGSF option(s) | 13w | 2019-06-03 | 2019-08-30 |  |  |  |  | 0d |  |  | CavedoniC_P [10%] | 52h | 4,519.84 |
| 170 | 1.4.2.2.5 | Prepare conceptual electrical power service plans for the proposed LGSF option(s) | 13w | 2019-06-03 | 2019-08-30 |  |  |  |  | 0d |  |  | KarewiczS_P [10%] | 52h | 4,519.84 |
| 171 | 1.4.2.2.6 | Prepare conceptual MEP cost and schedule estimates for the proposed LGSF option(s) | 6.4w | 2019-08-05 | 2019-09-17 | 170FS-4w |  |  |  | 0d |  |  | CavedoniC_P [10%]; KarewiczS_P [10%] | 51.2h | 4,450.3 |
| 172 | 1.4.2.2.7 | Prepare CoD MEP Documents | 2w | 2019-09-02 | 2019-09-13 |  |  |  |  | 0d |  | start no earlier than 2019-09-01 | CavedoniC_P [10%]; KangS_P [20%]; KarewiczS_P [10%]; MarinE_P [10%]; SchneiderT_P [10%] | 48h | 4,172.16 |
| 173 | 1.4.2.2.8 | Review and addressMEP CoD Comments, Concerns & Questions | 0.4w | 2019-09-27 | 2019-09-30 |  |  |  |  | 0d |  | start no earlier than 2019-09-27 | CavedoniC_P; KangS_P; KarewiczS_P [50%] | 40h | 3,476.8 |
| 174 | 1.4.2.3 | **Control Computer Software** | 30d | 2019-06-03 | 2019-07-12 |  |  |  |  | 0d |  |  |  | 160h | 13,290.4 |
| 175 | 1.4.2.3.1 | Refine laser to LIS electronics interface | 2w | 2019-06-03 | 2019-06-14 |  |  |  |  | 0d |  |  | KarewiczS_P [50%] | 40h | 3,476.8 |
| 176 | 1.4.2.3.2 | Define LIS changes to support multiple lasers | 2w | 2019-06-17 | 2019-06-28 | 175 |  |  |  | 0d |  |  | EbbersA_P [50%]; KarewiczS_P [50%] | 80h | 6,645.2 |
| 177 | 1.4.2.3.3 | Define motor control options for BIM/BTO | 2w | 2019-07-01 | 2019-07-12 | 176 |  |  |  | 0d |  |  | EbbersA_P [50%] | 40h | 3,168.4 |
| 178 | 1.4.3 | **Preliminary Design** | 172.5d | 2019-10-01 | 2020-05-28 |  | 2006-06-26 | 2007-05-09 | 45.51w? | 0d |  |  |  | 2602.2h | 224,613.82 |
| 179 | 1.4.3.1 | **Provide preliminary optical design concept for LGSF units that include Zemax optical design model of BTO, 3-D mechanical model layout of BTO, initial build and alignment plan, and cost analysis.** | 170d | 2019-10-01 | 2020-05-25 |  |  |  |  | 2.5d |  |  |  | 668h | 58,062.56 |
| 180 | 1.4.3.1.1 | Define full optical requirements for LGSF | 4w | 2019-10-01 | 2019-10-28 |  |  |  |  | 2.5d | 0d | start no earlier than 2019-10-01 | SchneiderT_P [50%] | 80h | 6,953.6 |
| 181 | 1.4.3.1.2 | Prepare preliminary optical design | 8w | 2019-10-29 | 2019-12-23 | 180 |  |  |  | 2.5d | 0d | finish no earlier than 2019-11-15 | SchneiderT_P [25%] | 80h | 6,953.6 |
| 182 | 1.4.3.1.3 | Prepare preliminary opto-mechanical design layout | 8w | 2019-12-24 | 2020-02-17 | 181 |  |  |  | 2.5d | 0d | finish no earlier than 2019-11-15 | SchneiderT_P [25%]; CavedoniC_P [20%] | 144h | 12,516.48 |
| 183 | 1.4.3.1.4 | Prepare preliminary design for BTO enclosure | 14w | 2020-02-18 | 2020-05-25 | 182 |  |  |  | 2.5d |  | finish no earlier than 2019-12-13 | SchneiderT_P [20%]; CavedoniC_P [20%]; KangS_P [20%]; KarewiczS_P [5%] | 364h | 31,638.88 |
| 184 | 1.4.3.2 | **Prepare MEP Deliverable for PD including 3-d mechanical layouts, mechanical assembly drawings, mechanical balancing plans and balancing hardware assembly drawings, mechanical mounting assembly drawings, electrical power plans and plumbing service plans.** | 172.5d | 2019-10-01 | 2020-05-28 |  |  |  |  | 0d |  |  |  | 1414.2h | 122,922.26 |
| 185 | 1.4.3.2.1 | Refine mechancial functional requirements for down selected LGSF option | 8.7w | 2019-10-01 | 2019-11-29 |  |  |  |  | 129d |  | start no earlier than 2019-10-01 | CavedoniC_P [20%] | 69.6h | 6,049.63 |
| 186 | 1.4.3.2.2 | Refine electrical functional requirements for down selected LGSF option | 8.7w | 2019-10-01 | 2019-11-29 |  |  |  |  | 129d |  | start no earlier than 2019-10-01 | KarewiczS_P [20%] | 69.6h | 6,049.63 |
| 187 | 1.4.3.2.3 | Refine plumbing functional requirements for down selected LGSF option | 8.7w | 2019-10-01 | 2019-11-29 |  |  |  |  | 129d |  | start no earlier than 2019-10-01 | CavedoniC_P [20%] | 69.6h | 6,049.63 |
| 188 | 1.4.3.2.4 | Define mechanical ICDs for down selected LGSF option | 6.7w | 2019-11-15 | 2020-01-01 |  |  |  |  | 106d |  | start no earlier than 2019-11-15 | CavedoniC_P [20%]; KangS_P [20%] | 107.2h | 9,317.82 |
| 189 | 1.4.3.2.5 | Define electrical ICDs for down selected LGSF option | 6.7w | 2019-11-15 | 2020-01-01 |  |  |  |  | 106d |  | start no earlier than 2019-11-15 | KarewiczS_P [10%] | 26.8h | 2,329.46 |
| 190 | 1.4.3.2.6 | Define plumbing ICDs for down selected LGSF option | 6.7w | 2019-11-15 | 2020-01-01 |  |  |  |  | 106d |  | start no earlier than 2019-11-15 | CavedoniC_P [10%] | 26.8h | 2,329.46 |
| 191 | 1.4.3.2.7 | Prepare preliminary mechanical layouts for down selected LGSF hardware (including necessary LLTs, LHs, ECs, BTOs & LHXs) | 23.3w | 2019-11-01 | 2020-04-13 |  |  |  |  | 33d |  | start no earlier than 2019-11-01 | CavedoniC_P [10%]; KangS_P [30%] | 372.8h | 32,403.78 |
| 192 | 1.4.3.2.8 | Prepare preliminary mechanical balancing plan and sequence of balancing for down selected LGSF | 23.3w | 2019-11-01 | 2020-04-13 |  |  |  |  | 33d |  | start no earlier than 2019-11-01 | CavedoniC_P [10%] | 93.2h | 8,100.94 |
| 193 | 1.4.3.2.9 | Prepare preliminary mechanical mounting assembly drawings for down selected LGSF | 23.3w | 2019-11-01 | 2020-04-13 |  |  |  |  | 33d |  | start no earlier than 2019-11-01 | CavedoniC_P [20%]; KangS_P [40%] | 198.4h | 17,244.93 |
| 194 | 1.4.3.2.10 | Prepare preliminary electrical power one-line diagrams for down selected LGSF | 13.7w | 2020-01-07 | 2020-04-10 |  |  |  |  | 34d |  | start no earlier than 2020-01-07 | KarewiczS_P [10%] | 54.8h | 4,763.22 |
| 195 | 1.4.3.2.11 | Prepare preliminary plumbing schematic for down selected LGSF | 16w | 2019-11-01 | 2020-02-20 |  |  |  |  | 69.5d |  | start no earlier than 2019-11-01 | CavedoniC_P [10%]; KangS_P [10%] | 128h | 11,125.76 |
| 196 | 1.4.3.2.12 | Prepare preliminary MEP cost estimates for down selected LGSF | 5.6w | 2020-03-04 | 2020-04-10 |  |  |  |  | 33.5d |  | start no earlier than 2020-03-04 | CavedoniC_P [10%]; KarewiczS_P [10%] | 44.8h | 3,894.02 |
| 197 | 1.4.3.2.13 | Prepare preliminary MEP schedule estimates for down selected LGSF | 5.6w | 2020-03-04 | 2020-04-10 |  |  |  |  | 33.5d |  | start no earlier than 2020-03-04 | CavedoniC_P [10%]; KarewiczS_P [10%] | 44.8h | 3,894.02 |
| 198 | 1.4.3.2.14 | Prepare technical specifications, solicit quotes and receive quotes for long-lead item(s) - LHX | 13.7w | 2020-01-07 | 2020-04-10 |  |  |  |  | 34d |  | start no earlier than 2020-01-07 | CavedoniC_P [10%]; KangS_P [10%]; KarewiczS_P [5%] | 43.4h | 3,772.33 |
| 199 | 1.4.3.2.15 | Prepare PD MEP Documents | 4.6w | 2020-04-15 | 2020-05-15 |  |  |  |  | 8.5d |  | start no earlier than 2020-04-15 | CavedoniC_P [50%]; KangS_P [80%]; KarewiczS_P [10%] | 34.4h | 2,990.05 |
| 200 | 1.4.3.2.16 | Review and address PD MEP Comments, Concerns & Questions | 0.7w | 2020-05-25 | 2020-05-28 |  |  |  |  | 0d |  | start no earlier than 2020-05-24 | CavedoniC_P; KangS_P; KarewiczS_P [50%] | 30h | 2,607.6 |

Notes:
- 178: Preliminary Design

| ID | WBS | Task | Duration | Start | Finish | Predecessors | Baseline start | Baseline finish | Baseline duration | Total slack | Free slack | Constraint | Resources | Work | Cost |
| --- | --- | --- | --- | --- | --- | --- | --- | --- | --- | --- | --- | --- | --- | --- | --- |
| 201 | 1.4.3.3 | **Control Computer Software** | 80d | 2019-10-01 | 2020-01-20 | 5 |  |  |  | 92.5d |  |  |  | 520h | 43,629 |
| 202 | 1.4.3.3.1 | Analyze all I/O needs | 2w | 2019-10-01 | 2019-10-14 |  |  |  |  | 92.5d | 0d |  | KarewiczS_P [50%] | 40h | 3,476.8 |
| 203 | 1.4.3.3.2 | Choose Motor Control solution for BIM/BTO | 2w | 2019-10-15 | 2019-10-28 | 202 |  |  |  | 92.5d | 0d |  | EbbersA_P [50%]; SchneiderT_P [50%] | 80h | 6,645.2 |
| 204 | 1.4.3.3.3 | Define BTO control architecture and functions. | 3w | 2019-10-29 | 2019-11-18 | 203 |  |  |  | 92.5d | 0d |  | EbbersA_P [50%]; RamboldW_P [50%] | 120h | 10,220.4 |
| 205 | 1.4.3.3.4 | Define interface/control functions for new heat exchanger | 1w | 2019-11-19 | 2019-11-25 | 204 |  |  |  | 92.5d | 0d |  | EbbersA_P [50%]; KarewiczS_P [50%] | 40h | 3,322.6 |
| 206 | 1.4.3.3.5 | Review current Toptica EPICS laser control solution | 2w | 2019-11-26 | 2019-12-09 | 205 |  |  |  | 92.5d | 0d |  | EbbersA_P [50%] | 40h | 3,168.4 |
| 207 | 1.4.3.3.6 | Define fast steering mirror (FSM) control | 2w | 2019-12-10 | 2019-12-23 | 206 |  |  |  | 92.5d | 0d |  | EbbersA_P [50%] | 40h | 3,168.4 |
| 208 | 1.4.3.3.7 | Define contents of consolidated Laser Control Console | 4w | 2019-12-24 | 2020-01-20 | 207 |  |  |  | 92.5d |  |  | EbbersA_P [50%]; RamboldW_P [50%] | 160h | 13,627.2 |
| 209 | 1.4.4 | **Critical Design** | 173.5d | 2020-06-01 | 2021-01-28 |  | 2007-06-01 | 2008-06-06 | 53.09w? | 0d |  |  |  | 3488.4h | 309,399.89 |
| 210 | 1.4.4.1 | **Provide finalized optical design and analysis for LGSF units. Provide finalized 3-D mechanical model layout as well as schematic drawings for all necessary parts. Provide electrical diagram for all electronic parts. Provide parts list and final prices.** | 160d | 2020-06-01 | 2021-01-08 |  |  |  |  | 13.5d |  |  |  | 924.8h | 82,127.26 |
| 211 | 1.4.4.1.1 | Prepare comprehensive optical layout and analysis | 8w | 2020-06-01 | 2020-07-24 |  |  |  |  | 133.5d |  | start no earlier than 2020-06-01 | SchneiderT_C [25%] | 80h | 7,162.4 |
| 212 | 1.4.4.1.2 | Prepare finalized opto-mechanical parts list | 8w | 2020-06-01 | 2020-07-24 |  |  |  |  | 13.5d | 0d | start no earlier than 2020-06-01 | SchneiderT_C [25%]; CavedoniC_C [20%] | 144h | 12,892.32 |
| 213 | 1.4.4.1.3 | Prepare 3-D model of BTO optical bench and enclosure | 16w | 2020-07-27 | 2020-11-13 | 212 |  |  |  | 53.5d |  | finish no earlier than 2020-08-01 | SchneiderT_C [20%]; CavedoniC_C [5%]; KangS_C [20%] | 288h | 25,784.64 |
| 214 | 1.4.4.1.4 | Prepare electrical diagram for opto-electronic parts | 16w | 2020-07-27 | 2020-11-13 | 212 |  |  |  | 13.5d | 0d | finish no earlier than 2020-08-01 | SchneiderT_C [2%]; KarewiczS_C [20%] | 140.8h | 12,605.82 |
| 215 | 1.4.4.1.5 | Prepare build, integration, and testing plans for LGSF units | 8w | 2020-11-16 | 2021-01-08 | 214 |  |  |  | 13.5d |  | finish no earlier than 2020-09-01 | SchneiderT_C [50%]; CavedoniC_C [25%]; Tech2_C [5%]; Tech3_C [5%] | 272h | 23,682.08 |
| 216 | 1.4.4.2 | **Prep MEP Delivs for CD including 3-d mech layouts, assem & fab drawings, mech balancing plans & HW assem & fab drawings, mech mounting plans, assem & fab drawings, electrical power plans install drawings & plumb service plans & install & spec procures** | 173.5d | 2020-06-01 | 2021-01-28 |  |  |  |  | 0d |  |  |  | 1771.6h | 158,611.35 |
| 217 | 1.4.4.2.1 | Release and track purchase order(s) for agreed long lead MEP items (LHX) | 34w | 2020-06-01 | 2021-01-22 |  |  |  |  | 3.5d |  | start no earlier than 2020-06-01 | CavedoniC_C [10%] | 136h | 12,176.08 |
| 218 | 1.4.4.2.2 | Refine mechanical functional requirements | 4w | 2020-06-01 | 2020-06-26 |  |  |  |  | 3.5d | 0d | start no earlier than 2020-06-01 | CavedoniC_C [10%]; KangS_C [10%] | 32h | 2,864.96 |
| 219 | 1.4.4.2.3 | Refine electrical functional requirements | 4w | 2020-06-01 | 2020-06-26 |  |  |  |  | 53.5d | 0d | start no earlier than 2020-06-01 | KarewiczS_C [10%] | 16h | 1,432.48 |
| 220 | 1.4.4.2.4 | Refine plumbing functional requirements | 4w | 2020-06-01 | 2020-06-26 |  |  |  |  | 133.5d | 0d | start no earlier than 2020-06-01 | CavedoniC_C [20%] | 32h | 2,864.96 |
| 221 | 1.4.4.2.5 | Refine mechanical ICDs | 4w | 2020-06-29 | 2020-07-24 | 218 |  |  |  | 3.5d | 0d | start no earlier than 2020-06-01 | CavedoniC_C [20%]; KangS_C [20%] | 64h | 5,729.92 |
| 222 | 1.4.4.2.6 | Refine electrical ICDs | 4w | 2020-06-29 | 2020-07-24 | 219 |  |  |  | 53.5d | 0d | start no earlier than 2020-06-01 | KarewiczS_C [10%] | 16h | 1,432.48 |
| 223 | 1.4.4.2.7 | Refine plumbing ICDs | 4w | 2020-06-29 | 2020-07-24 | 220 |  |  |  | 133.5d |  | start no earlier than 2020-06-01 | CavedoniC_C [10%]; KangS_C [10%] | 32h | 2,864.96 |
| 224 | 1.4.4.2.8 | Prepare critical mechanical layout, assembly, and fab drawings | 16w | 2020-07-27 | 2020-11-13 | 221 |  |  |  | 53.5d |  | start no earlier than 2020-06-01 | CavedoniC_C [10%]; KangS_C [30%] | 128h | 11,459.84 |
| 225 | 1.4.4.2.9 | Prepare critical mechanical balancing plan and sequence of balancing telescope thru Build Sequence | 16w | 2020-07-27 | 2020-11-13 | 221 |  |  |  | 53.5d |  | start no earlier than 2020-06-01 | CavedoniC_C [20%] | 128h | 11,459.84 |
| 226 | 1.4.4.2.10 | Prepare critical mechanical mounting assembly and fab drawings | 16w | 2020-07-27 | 2020-11-13 | 221 |  |  |  | 53.5d |  | start no earlier than 2020-06-01 | CavedoniC_C [10%]; KangS_C [40%] | 320h | 28,649.6 |
| 227 | 1.4.4.2.11 | Prepare critical electrical power fab drawings | 16w | 2020-07-27 | 2020-11-13 | 222 |  |  |  | 53.5d |  | start no earlier than 2020-06-01 | KarewiczS_C [30%] | 192h | 17,189.76 |
| 228 | 1.4.4.2.12 | Prepare critical plumbing schematic and fab drawings | 20w | 2020-07-27 | 2020-12-11 | 221 |  |  |  | 3.5d | 0d | start no earlier than 2020-06-01 | CavedoniC_C [10%] | 80h | 7,162.4 |
| 229 | 1.4.4.2.13 | Prepare critical MEP cost estimates | 10w | 2020-11-16 | 2021-01-22 | 228FS-4w |  |  |  | 3.5d |  |  | CavedoniC_C [10%]; KarewiczS_C [10%] | 80h | 7,162.4 |
| 230 | 1.4.4.2.14 | Prepare critical MEP schedule estimates | 10w | 2020-11-16 | 2021-01-22 | 228FS-4w |  |  |  | 3.5d |  |  | CavedoniC_C [10%]; KarewiczS_C [10%] | 80h | 7,162.4 |
| 231 | 1.4.4.2.15 | Prepare CD MEP Documents | 7.6w | 2020-11-30 | 2021-01-20 | 228FS-2w |  |  |  | 5.5d |  | start no earlier than 2020-11-23 | CavedoniC_C [50%]; KangS_C [80%]; KarewiczS_C [10%] | 425.6h | 38,103.97 |
| 232 | 1.4.4.2.16 | Review and address CD MEP Comments, Concerns & Questions | 0.1w | 2021-01-28 | 2021-01-28 |  |  |  |  | 0d |  | start no earlier than 2021-01-28 | CavedoniC_C; KangS_C; KarewiczS_C [50%] | 10h | 895.3 |

Notes:
- 209: Critical Design

| ID | WBS | Task | Duration | Start | Finish | Predecessors | Baseline start | Baseline finish | Baseline duration | Total slack | Free slack | Constraint | Resources | Work | Cost |
| --- | --- | --- | --- | --- | --- | --- | --- | --- | --- | --- | --- | --- | --- | --- | --- |
| 233 | 1.4.4.3 | **Control Computer Software** | 130d | 2020-06-01 | 2020-11-27 | 8 |  |  |  | 43.5d |  |  |  | 792h | 68,661.28 |
| 234 | 1.4.4.3.1 | Design BTO software (produce detailed design doc) | 6w | 2020-06-01 | 2020-07-10 |  |  |  |  | 43.5d | 0d |  | EbbersA_C [50%]; RamboldW_C [50%] | 240h | 21,054 |
| 235 | 1.4.4.3.2 | Design LIS changes (produce detailed design doc) | 2w | 2020-07-13 | 2020-07-24 | 234 |  |  |  | 43.5d | 0d |  | EbbersA_C [50%]; KarewiczS_C [50%] | 80h | 6,844.8 |
| 236 | 1.4.4.3.3 | Design interface changes (if needed) | 2w | 2020-07-27 | 2020-08-07 | 235 |  |  |  | 43.5d | 0d |  | EbbersA_C [50%] | 40h | 3,263.6 |
| 237 | 1.4.4.3.4 | Design fast steering mirror (FSM) control | 4w | 2020-08-10 | 2020-09-04 | 236 |  |  |  | 43.5d | 0d |  | EbbersA_C [50%] | 80h | 6,527.2 |
| 238 | 1.4.4.3.5 | Design Laser Control Console (produce detailed design doc) | 4w | 2020-09-07 | 2020-10-02 | 237 |  |  |  | 43.5d | 0d |  | EbbersA_C [50%]; RamboldW_C [50%] | 160h | 14,036 |
| 239 | 1.4.4.3.6 | Design interface to new heat exchanger | 8w | 2020-10-05 | 2020-11-27 | 238 |  |  |  | 43.5d |  |  | EbbersA_C [10%]; KarewiczS_C [50%] | 192h | 16,935.68 |
| 240 | 1.4.5 | **Build** | 530d | 2021-01-11 | 2023-01-21 |  | 2008-06-10 | 2009-09-18 | 66.67w | 0d |  |  |  | 8884.77h | 723,741.07 |
| 241 | 1.4.5.1 | **Order and receive optical parts and tools necessary to build and align LGSF units. Build BTO units in lab and order BTO enclosure from vendor after soliciting quotes. Integrate, align, and test BTO, Laser Head, and LLT in lab before attaching components.** | 434d | 2021-02-02 | 2022-09-30 |  |  |  |  | 80d |  |  |  | 2359.68h | 191,994.72 |
| 242 | 1.4.5.1.1 | Order optical and opto-mechanical components | 2w | 2021-02-02 | 2021-02-15 |  |  |  |  | 504d |  | finish no earlier than 2021-02-15 | SchneiderT_B [75%] | 60h | 5,533.2 |
| 243 | 1.4.5.1.2 | Solicit quotes for BTO enclosure builds | 2w | 2021-02-02 | 2021-02-15 |  |  |  |  | 504d |  | finish no earlier than 2021-02-15 | SchneiderT_B [5%]; CavedoniC_B [5%] | 8h | 737.76 |
| 244 | 1.4.5.1.3 | Receive BTO enclosures | 1w | 2021-05-03 | 2021-05-08 |  |  |  |  | 445d |  | finish no earlier than 2021-05-08 | SchneiderT_B [10%]; CavedoniC_B [10%] | 8h | 737.76 |
| 245 | 1.4.5.1.4 | Assemble optical components of 3 BTO optical benches and enclosures in lab | 6w | 2021-06-04 | 2021-07-15 |  |  |  |  | 396d |  | finish no earlier than 2021-07-15 | SchneiderT_B [50%]; Tech3_B | 360h | 28,022.4 |
| 246 | 1.4.5.1.5 | Build software controls for BTO opto-electronics | 12w | 2021-03-10 | 2021-06-01 |  |  |  |  | 428d |  | finish no earlier than 2021-06-01 | EbbersA_B | 480h | 40,339.2 |
| 247 | 1.4.5.1.6 | Wire BTO opto-electronics | 8w | 2021-06-07 | 2021-08-01 |  |  |  |  | 385d |  | finish no earlier than 2021-08-01 | Tech2_B [50%] | 160h | 11,304 |
| 248 | 1.4.5.1.7 | Test full BTO functionality in lab with alignment laser | 2w | 2021-06-18 | 2021-07-01 |  |  |  |  | 406d |  | finish no earlier than 2021-07-01 | SchneiderT_B [50%]; EbbersA_B [50%]; KarewiczS_B [50%] | 51.11h | 4,386.26 |
| 249 | 1.4.5.1.8 | **Laser System #1** | 87d | 2021-10-04 | 2022-02-01 |  |  |  |  | 92d | 23d |  |  | 568.57h | 46,066.86 |
| 250 | 1.4.5.1.8.1 | Receive LLT #1 for acceptance test in lab | 2w | 2021-10-04 | 2021-10-15 |  |  |  |  | 169d |  | finish no earlier than 2021-10-15 | SchneiderT_B [50%]; Tech3_B [50%] | 48.57h | 3,616.46 |
| 251 | 1.4.5.1.8.2 | Integrate LLT #1 on BTO #1 optical bench for testing | 2w | 2021-10-19 | 2021-11-01 |  |  |  |  | 158d |  | finish no earlier than 2021-11-01 | SchneiderT_B [50%]; Tech3_B [50%] | 80h | 6,514.8 |
| 252 | 1.4.5.1.8.3 | Receive Toptica laser #1, conduct acceptance testing in lab | 2w | 2021-11-02 | 2021-11-15 |  |  |  |  | 148d |  | finish no earlier than 2021-11-15 | SchneiderT_B [50%]; Tech3_B [50%] | 80h | 6,514.8 |
| 253 | 1.4.5.1.8.4 | Integrate Toptica laser #1, LLT #1, and optical bench for testing and qualification | 2w | 2021-11-18 | 2021-12-01 |  |  |  |  | 136d |  | finish no earlier than 2021-12-01 | SchneiderT_B [50%]; Tech3_B [50%] | 80h | 6,514.8 |
| 254 | 1.4.5.1.8.5 | Receive LLT #2 for acceptance test in lab | 2w | 2021-12-20 | 2022-01-01 |  |  |  |  | 114d |  | finish no earlier than 2022-01-01 | SchneiderT_B [50%]; Tech3_B [50%] | 80h | 6,514.8 |
| 255 | 1.4.5.1.8.6 | Integrate LLT #2 onto LGSF 1 | 2w | 2022-01-03 | 2022-01-15 |  |  |  |  | 104d |  | finish no earlier than 2022-01-15 | SchneiderT_B [50%]; Tech3_B [50%] | 80h | 6,514.8 |
| 256 | 1.4.5.1.8.7 | Test full functionality of LGSF 1 in lab | 2w | 2022-01-19 | 2022-02-01 |  |  |  |  | 92d |  | finish no earlier than 2022-02-01 | SchneiderT_B; EbbersA_B; Tech3_B [50%] | 120h | 9,876.4 |

Notes:
- 240: Build / Implement / Incrementally Integrate & Test

| ID | WBS | Task | Type | Duration | Start | Finish | Total slack | Free slack | Constraint | Resources | Work | Cost |
| --- | --- | --- | --- | --- | --- | --- | --- | --- | --- | --- | --- | --- |
| 257 | 1.4.5.1.9 | **Laser System #2** |  | 73d | 2022-02-02 | 2022-05-15 | 95d | 36d |  |  | 600h | 48,965.2 |
| 258 | 1.4.5.1.9.1 | Receive LLT #3 for acceptance test in lab |  | 2w | 2022-02-02 | 2022-02-15 | 158d |  | finish no earlier than 2022-02-15 | SchneiderT_B [50%]; Tech3_B [50%] | 80h | 6,514.8 |
| 259 | 1.4.5.1.9.2 | Integrate LLT #3 on BTO #2 for testing |  | 2w | 2022-02-16 | 2022-03-01 | 148d |  | finish no earlier than 2022-03-01 | SchneiderT_B [50%]; Tech3_B [50%] | 80h | 6,514.8 |
| 260 | 1.4.5.1.9.3 | Receive LLT #4 for acceptance test in lab |  | 2w | 2022-03-02 | 2022-03-15 | 138d |  | finish no earlier than 2022-03-15 | SchneiderT_B [50%]; Tech3_B [50%] | 80h | 6,514.8 |
| 261 | 1.4.5.1.9.4 | Integrate LLT #4 on BTO #2 for testing |  | 2w | 2022-03-21 | 2022-04-01 | 125d |  | finish no earlier than 2022-04-01 | SchneiderT_B [50%]; Tech3_B [50%] | 80h | 6,514.8 |
| 262 | 1.4.5.1.9.5 | Receive Toptica laser #2, conduct acceptance testing in lab |  | 2w | 2022-04-04 | 2022-04-15 | 115d |  | finish no earlier than 2022-04-15 | SchneiderT_B [50%]; Tech3_B [50%] | 80h | 6,514.8 |
| 263 | 1.4.5.1.9.6 | Integrate Toptica laser #2, LLTs #3+4, and BTO for testing and qualification (LGSF 2) |  | 2w | 2022-04-18 | 2022-05-01 | 105d |  | finish no earlier than 2022-05-01 | SchneiderT_B [50%]; Tech3_B [50%] | 80h | 6,514.8 |
| 264 | 1.4.5.1.9.7 | Test full functionality of LGSF 2 in lab |  | 2w | 2022-05-02 | 2022-05-15 | 95d |  | finish no earlier than 2022-05-15 | SchneiderT_B; EbbersA_B; Tech3_B [50%] | 120h | 9,876.4 |
| 265 | 1.4.5.1.10 | **Laser System #3 (if needed)** |  | 66d | 2022-06-01 | 2022-09-01 | 101d | 47d |  |  |  |  |
| 266 | 1.4.5.1.10.1 | Receive LLT #5 for acceptance test in lab | milestone | 0w | 2022-06-01 | 2022-06-01 | 167d |  | finish no earlier than 2022-06-01 | SchneiderT_B [50%]; Tech3_B [50%] |  |  |
| 267 | 1.4.5.1.10.2 | Integrate LLT #5 on BTO #3 for testing | milestone | 0w | 2022-06-15 | 2022-06-15 | 157d |  | finish no earlier than 2022-06-15 | SchneiderT_B [50%]; Tech3_B [50%] |  |  |
| 268 | 1.4.5.1.10.3 | Receive LLT #6 for acceptance test in lab | milestone | 0w | 2022-07-01 | 2022-07-01 | 145d |  | finish no earlier than 2022-07-01 | SchneiderT_B [50%]; Tech3_B [50%] |  |  |
| 269 | 1.4.5.1.10.4 | Integrate LLT #6 on BTO #3 for testing | milestone | 0w | 2022-07-15 | 2022-07-15 | 135d |  | finish no earlier than 2022-07-15 | SchneiderT_B [50%]; Tech3_B [50%] |  |  |
| 270 | 1.4.5.1.10.5 | Remove old Toptica laser from telescope for integration into BTO #3 | milestone | 0w | 2022-08-01 | 2022-08-01 | 124d |  | finish no earlier than 2022-08-01 | SchneiderT_B; CavedoniC_B; Tech1_B [200%]; Tech2_B; Tech3_B |  |  |
| 271 | 1.4.5.1.10.6 | Integrate Toptica laser #3, LLTs #5+6, and BTO #3 for testing and qualification (LGSF 3) | milestone | 0w | 2022-08-15 | 2022-08-15 | 114d |  | finish no earlier than 2022-08-15 | SchneiderT_B [50%]; Tech3_B [50%] |  |  |
| 272 | 1.4.5.1.10.7 | Test full functionality of LGSF 3 in lab | milestone | 0w | 2022-09-01 | 2022-09-01 | 101d |  | finish no earlier than 2022-09-01 | SchneiderT_B; EbbersA_B; Tech3_B [50%] |  |  |
| 273 | 1.4.5.1.11 | BTO optics detailed documentation |  | 80w | 2021-03-22 | 2022-09-30 | 80d |  | finish no earlier than 2022-09-30 | SchneiderT_B [2%] | 64h | 5,902.08 |
| 274 | 1.4.5.2 | **Receive, Build and Install MEP hardware and systems including all necessary alignment tools, mounting hardware and telescope balancing hardware for LGS** |  | 530d | 2021-01-11 | 2023-01-21 | 0d |  |  |  | 4765.09h | 377,946.35 |
| 275 | 1.4.5.2.1 | Solicit final quotes and release orders for all fabricated hardware including LLT mounts, LH mounts, EC mounts, BTO mounts, LHX mounts, alignment tools and balancing hardware |  | 12w | 2021-02-08 | 2021-05-01 | 450d |  | finish no earlier than 2021-05-01 | CavedoniC_B [20%] | 96h | 8,853.12 |
| 276 | 1.4.5.2.2 | Solicit final quotes and release orders for all electrical components including cabling, electrical devices, cable trays and enclosures |  | 8w | 2021-03-08 | 2021-05-01 | 450d |  | finish no earlier than 2021-05-01 | KarewiczS_B [10%]; Tech2_B [10%] | 61.09h | 5,006.31 |
| 277 | 1.4.5.2.3 | Solicit final quotes and release orders for all plumbing components including hoses, control valves, sensors and gauges |  | 8w | 2021-03-08 | 2021-05-01 | 450d |  | finish no earlier than 2021-05-01 | CavedoniC_B [10%] | 32h | 2,951.04 |
| 278 | 1.4.5.2.4 | Receive and perform on-site off-telescope LHX acceptance & verification test (must complete prior testing Toptica lasers in Lab) |  | 2w | 2021-04-19 | 2021-05-01 | 450d |  | finish no earlier than 2021-05-01 | CavedoniC_B [25%]; KarewiczS_B [10%]; Tech1_B [5%]; EbbersA_B [10%]; Tech2_B [10%] | 48h | 4,102.28 |
| 279 | 1.4.5.2.5 | Install and test LHX cooling system including end-of-day telescope balancing |  | 8w | 2021-03-08 | 2021-05-01 | 450d |  | finish no earlier than 2021-05-01 | CavedoniC_B [20%]; KarewiczS_B [10%]; Tech1_B [50%]; EbbersA_B [10%]; Tech2_B [10%] | 320h | 25,107.2 |
| 280 | 1.4.5.2.6 | Complete necessary Job Safety Analysis (JSA) for the installation of hardware on telescope |  | 16w | 2021-01-11 | 2021-05-01 | 450d |  | finish no earlier than 2021-05-01 | CavedoniC_B [5%]; Tech1_B [5%] | 64h | 5,211.84 |
| 281 | 1.4.5.2.7 | Receive, assembly and prep off-telescope Electrical hardware including conduit runs, cable trays, enclosures, connectors and patch panels |  | 10w | 2021-02-22 | 2021-05-01 | 450d |  | finish no earlier than 2021-05-01 | KarewiczS_B [10%]; Tech2_B [30%] | 120h | 9,340.8 |
| 282 | 1.4.5.2.8 | Receive, assembly and prep off-telescope Plumbing hardware including hose runs, cable trays, valves , meters & sensors |  | 12w | 2021-02-08 | 2021-05-01 | 450d |  | finish no earlier than 2021-05-01 | CavedoniC_B [10%]; KarewiczS_B [10%]; Tech2_B [20%]; Tech1_B [20%] | 288h | 22,417.92 |
| 283 | 1.4.5.2.9 | Receive, assemble and prep off-telescope Balancing Hardware |  | 8w | 2021-03-08 | 2021-05-01 | 450d |  | finish no earlier than 2021-05-01 | CavedoniC_B [5%]; Tech2_B [15%] | 64h | 4,866.72 |
| 284 | 1.4.5.2.10 | Receive, assembly and prep off-telescope Mechanical hardware including EC/LH mounting hardware, BTO mounting hardware, LLT mounting hardware and alignment hardware |  | 24w | 2021-05-18 | 2021-11-01 | 319d |  | finish no earlier than 2021-11-01 | CavedoniC_B [20%]; KangS_B [20%]; Tech1_B [20%] | 576h | 48,977.28 |
| 285 | 1.4.5.2.11 | Demo out and/or relocate telescope hardware and services interfering with LGSF installation including (+/-) Y Center Section items |  | 12w | 2021-08-10 | 2021-11-01 | 319d |  | finish no earlier than 2021-11-01 | CavedoniC_B [10%]; KangS_B [10%]; Tech1_B [40%] | 288h | 22,417.92 |
| 286 | 1.4.5.2.12 | Install Electrical hardware including conduit runs, cable trays, enclosures & connectors including daily end-of-day telescope balancing |  | 16w | 2021-07-13 | 2021-11-01 | 319d |  | finish no earlier than 2021-11-01 | CavedoniC_B [5%]; KarewiczS_B [10%]; Tech2_B [40%] | 352h | 26,939.52 |
| 287 | 1.4.5.2.13 | Install mechanical balancing hardware including daily end-of-day telescope balancing |  | 10w | 2021-08-24 | 2021-11-01 | 319d |  | finish no earlier than 2021-11-01 | CavedoniC_B [10%]; Tech1_B [40%] | 200h | 14,992.8 |
| 288 | 1.4.5.2.14 | Install telescope pluimbing services including daily end-of-day telescope balacing |  | 12w | 2021-08-10 | 2021-11-01 | 319d |  | finish no earlier than 2021-11-01 | CavedoniC_B [10%]; Tech1_B [40%] | 240h | 17,991.36 |
| 289 | 1.4.5.2.15 | Install mechanical interface hardware for LLTs, BTOs & LHs includng daily end-of-day telescope balancing |  | 16w | 2021-11-10 | 2022-03-01 | 233d |  | finish no earlier than 2022-03-01 | CavedoniC_B [10%]; Tech1_B [40%]; KangS_B [5%] | 352h | 26,939.52 |

| ID | WBS | Task | Type | Duration | Start | Finish | Predecessors | Total slack | Constraint | Resources | Work | Cost |
| --- | --- | --- | --- | --- | --- | --- | --- | --- | --- | --- | --- | --- |
| 290 | 1.4.5.2.16 | **Laser System #1** |  | 99d | 2022-03-07 | 2022-07-21 | 249 | 0d |  |  | 944h | 74,798.08 |
| 291 | 1.4.5.2.16.1 | Install Laser System #1 equipment mounts (EC/LH/BTO/LLT) including end-of-day telescope balacing |  | 6w | 2022-03-07 | 2022-04-15 |  | 69d | finish no earlier than 2022-04-15 | CavedoniC_B [20%]; Tech1_B [40%] | 144h | 11,208.96 |
| 292 | 1.4.5.2.16.2 | Install Laser System #1 Toptica EC & LH includng end-of-day telescope balancing |  | 4w | 2022-03-21 | 2022-04-15 |  | 69d | finish no earlier than 2022-04-15 | CavedoniC_B [20%]; Tech1_B [40%] | 96h | 7,472.64 |
| 293 | 1.4.5.2.16.3 | Install Laser System # 1 BTO including end-of-day telescope balancing |  | 4w | 2022-03-21 | 2022-04-15 |  | 69d | finish no earlier than 2022-04-15 | CavedoniC_B [20%]; Tech1_B [40%] | 96h | 7,472.64 |
| 294 | 1.4.5.2.16.4 | Install laser System #1 LLTs A&B including end-of-day telescope balancing |  | 4w | 2022-03-21 | 2022-04-15 |  | 69d | finish no earlier than 2022-04-15 | CavedoniC_B [20%]; Tech1_B [40%] | 96h | 7,472.64 |
| 295 | 1.4.5.2.16.5 | Mechanically align Laser System #1 |  | 4w | 2022-04-18 | 2022-05-15 |  | 49d | finish no earlier than 2022-05-15 | CavedoniC_B [20%]; Tech1_B [40%] | 96h | 7,472.64 |
| 296 | 1.4.5.2.16.6 | Install and test power to Laser System #1 |  | 4w | 2022-04-18 | 2022-05-15 |  | 49d | finish no earlier than 2022-05-15 | Tech1_B [20%]; Tech2_B [40%] | 96h | 6,782.4 |
| 297 | 1.4.5.2.16.7 | Install and test cooing to Laser System #1 |  | 2w | 2022-05-02 | 2022-05-15 |  | 49d | finish no earlier than 2022-05-15 | CavedoniC_B [20%]; Tech1_B [40%] | 48h | 3,736.32 |
| 298 | 1.4.5.2.16.8 | Install and test communicaiton and control to Laser System #1 |  | 4w | 2022-05-19 | 2022-06-15 |  | 26d | finish no earlier than 2022-06-15 | KarewiczS_B [20%]; EbbersA_B [20%]; Tech2_B [20%] | 96h | 7,901.12 |
| 299 | 1.4.5.2.16.9 | Optically align Laser System #1 |  | 2w | 2022-06-20 | 2022-07-01 |  | 14d | finish no earlier than 2022-07-01 | Tech3_B [40%]; SchneiderT_B [20%] | 48h | 3,736.32 |
| 300 | 1.4.5.2.16.10 | Integrate and commission Laser System #1 |  | 4w | 2022-06-24 | 2022-07-21 |  | 0d | finish no earlier than 2022-07-21 | SchneiderT_B [20%]; CavedoniC_B [20%]; KarewiczS_B [20%]; EbbersA_B [20%] | 128h | 11,542.4 |
| 301 | 1.4.5.2.17 | **Laser System #2** |  | 79d | 2022-07-05 | 2022-10-21 | 257 | 0d |  |  | 720h | 57,032.64 |
| 302 | 1.4.5.2.17.1 | Install Laser System #2 equipment mounts (EC/LH/BTO/LLT) including end-of-day telescope balacing |  | 4w | 2022-07-05 | 2022-08-01 |  | 59d | finish no earlier than 2022-08-01 | CavedoniC_B [20%]; Tech1_B [40%] | 96h | 7,472.64 |
| 303 | 1.4.5.2.17.2 | Install Laser System #2 Toptica EC & LH includng end-of-day telescope balancing |  | 3w | 2022-07-12 | 2022-08-01 |  | 59d | finish no earlier than 2022-08-01 | CavedoniC_B [20%]; Tech1_B [40%] | 72h | 5,604.48 |
| 304 | 1.4.5.2.17.3 | Install Laser System #2 BTO including end-of-day telescope balancing |  | 3w | 2022-07-12 | 2022-08-01 |  | 59d | finish no earlier than 2022-08-01 | CavedoniC_B [20%]; Tech1_B [40%] | 72h | 5,604.48 |
| 305 | 1.4.5.2.17.4 | Install laser System #2 LLTs A&B including end-of-day telescope balancing |  | 3w | 2022-07-12 | 2022-08-01 |  | 59d | finish no earlier than 2022-08-01 | CavedoniC_B [20%]; Tech1_B [40%] | 72h | 5,604.48 |
| 306 | 1.4.5.2.17.5 | Mechanically align Laser System #2 |  | 3w | 2022-08-01 | 2022-08-21 |  | 45d | finish no earlier than 2022-08-21 | CavedoniC_B [20%]; Tech1_B [40%] | 72h | 5,604.48 |
| 307 | 1.4.5.2.17.6 | Install and test power to Laser System #2 |  | 3w | 2022-08-01 | 2022-08-21 |  | 45d | finish no earlier than 2022-08-21 | Tech1_B [20%]; Tech2_B [40%] | 72h | 5,086.8 |
| 308 | 1.4.5.2.17.7 | Install and test cooing to Laser System #2 |  | 2w | 2022-08-08 | 2022-08-21 |  | 45d | finish no earlier than 2022-08-21 | CavedoniC_B [20%]; Tech1_B [40%] | 48h | 3,736.32 |
| 309 | 1.4.5.2.17.8 | Install and test communicaiton and control to Laser System #2 |  | 3w | 2022-08-25 | 2022-09-14 |  | 27d | finish no earlier than 2022-09-14 | KarewiczS_B [20%]; EbbersA_B [20%]; Tech2_B [20%] | 72h | 5,925.84 |
| 310 | 1.4.5.2.17.9 | Optically align Laser System #2 |  | 2w | 2022-09-19 | 2022-10-01 |  | 15d | finish no earlier than 2022-10-01 | Tech3_B [40%]; SchneiderT_B [20%] | 48h | 3,736.32 |
| 311 | 1.4.5.2.17.10 | Integrate and commission Laser System #2 |  | 3w | 2022-10-03 | 2022-10-21 |  | 0d | finish no earlier than 2022-10-21 | SchneiderT_B [20%]; CavedoniC_B [20%]; KarewiczS_B [20%]; EbbersA_B [20%] | 96h | 8,656.8 |
| 312 | 1.4.5.2.18 | **Laser System #3 (if needed)** |  | 54d | 2022-11-07 | 2023-01-21 | 265 | 0d |  |  |  |  |
| 313 | 1.4.5.2.18.1 | Install Laser System #3 equipment mounts (EC/LH/BTO/LLT) including end-of-day telescope balacing | milestone | 0w | 2022-11-07 | 2022-11-07 |  | 54d | finish no earlier than 2022-11-07 | CavedoniC_B [20%]; Tech1_B [40%] |  |  |
| 314 | 1.4.5.2.18.2 | Install Laser System #3 Toptica EC & LH includng end-of-day telescope balancing | milestone | 0w | 2022-11-21 | 2022-11-21 |  | 44d | finish no earlier than 2022-11-21 | CavedoniC_B [20%]; Tech1_B [40%] |  |  |
| 315 | 1.4.5.2.18.3 | Install Laser System #3 BTO including end-of-day telescope balancing | milestone | 0w | 2022-11-21 | 2022-11-21 |  | 44d | finish no earlier than 2022-11-21 | CavedoniC_B [20%]; Tech1_B [40%] |  |  |
| 316 | 1.4.5.2.18.4 | Install laser System #3 LLTs A&B including end-of-day telescope balancing | milestone | 0w | 2022-11-21 | 2022-11-21 |  | 44d | finish no earlier than 2022-11-21 | CavedoniC_B [20%]; Tech1_B [40%] |  |  |
| 317 | 1.4.5.2.18.5 | Mechanically align Laser System #3 | milestone | 0w | 2022-12-07 | 2022-12-07 |  | 32d | finish no earlier than 2022-12-07 | CavedoniC_B [20%]; Tech1_B [40%] |  |  |
| 318 | 1.4.5.2.18.6 | Install and test power to Laser System #3 | milestone | 0w | 2022-12-07 | 2022-12-07 |  | 32d | finish no earlier than 2022-12-07 | Tech1_B [20%]; Tech2_B [40%] |  |  |
| 319 | 1.4.5.2.18.7 | Install and test cooing to Laser System #3 | milestone | 0w | 2022-12-07 | 2022-12-07 |  | 32d | finish no earlier than 2022-12-07 | CavedoniC_B [20%]; Tech1_B [40%] |  |  |
| 320 | 1.4.5.2.18.8 | Install and test communicaiton and control to Laser System #3 | milestone | 0w | 2022-12-14 | 2022-12-14 |  | 27d | finish no earlier than 2022-12-14 | KarewiczS_B [20%]; EbbersA_B [20%]; Tech2_B [20%] |  |  |
| 321 | 1.4.5.2.18.9 | Optically align Laser System #3 | milestone | 0w | 2022-12-21 | 2022-12-21 |  | 22d | finish no earlier than 2022-12-21 | Tech3_B [40%]; SchneiderT_B [20%] |  |  |
| 322 | 1.4.5.2.18.10 | Integrate and commission Laser System #3 | milestone | 0w | 2023-01-21 | 2023-01-21 |  | 0d | finish no earlier than 2023-01-21 | SchneiderT_B [20%]; CavedoniC_B [20%]; KarewiczS_B [20%]; EbbersA_B [20%] |  |  |

| ID | WBS | Task | Duration | Start | Finish | Predecessors | Baseline start | Baseline finish | Baseline duration | Total slack | Free slack | Constraint | Resources | Work | Cost |
| --- | --- | --- | --- | --- | --- | --- | --- | --- | --- | --- | --- | --- | --- | --- | --- |
| 323 | 1.4.5.3 | **Control Computer Software** | 340d | 2021-02-01 | 2022-05-20 | 11 |  |  |  | 175d |  |  |  | 1760h | 153,800 |
| 324 | 1.4.5.3.1 | Implement LIS design in PLC (includes BTO door switches) | 16w | 2021-02-01 | 2021-05-21 |  |  |  |  | 175d | 0d |  | KarewiczS_B [50%] | 320h | 29,510.4 |
| 325 | 1.4.5.3.2 | Implement LIS design in EPICS (providing UI for PLC implementation) | 8w | 2021-05-24 | 2021-07-16 | 324 |  |  |  | 175d | 0d |  | EbbersA_B [50%] | 160h | 13,446.4 |
| 326 | 1.4.5.3.3 | Implement LHX interface in PLC | 20w | 2021-05-24 | 2021-10-08 | 324 |  |  |  | 335d |  |  | KarewiczS_B [50%] | 400h | 36,888 |
| 327 | 1.4.5.3.4 | Implement LHX interface in EPICS (providing UI for PLC implementation) | 4w | 2021-07-19 | 2021-08-13 | 325 |  |  |  | 175d | 0d |  | EbbersA_B [50%] | 80h | 6,723.2 |
| 328 | 1.4.5.3.5 | Implement changes to TLEI (if needed) | 4w | 2021-08-16 | 2021-09-10 | 327 |  |  |  | 175d | 0d |  | EbbersA_B [50%] | 80h | 6,723.2 |
| 329 | 1.4.5.3.6 | Implement BTO | 24w | 2021-09-13 | 2022-02-25 | 328 |  |  |  | 175d | 0d |  | EbbersA_B [50%] | 480h | 40,339.2 |
| 330 | 1.4.5.3.7 | Implement fast steering mirror (FSM) control | 4w | 2022-02-28 | 2022-03-25 | 329 |  |  |  | 175d | 0d |  | EbbersA_B [50%] | 80h | 6,723.2 |
| 331 | 1.4.5.3.8 | Implement Laser Control Console | 8w | 2022-03-28 | 2022-05-20 | 330 |  |  |  | 175d |  |  | EbbersA_B [50%] | 160h | 13,446.4 |
| 332 | 1.4.6 | **Integrate and Test (I&T)** | 379d | 2022-10-04 | 2024-03-15 |  | 2009-09-21 | 2009-12-29 | 14.14w? | 0d |  |  |  | 1880h | 179,927.6 |
| 333 | 1.4.6.1 | Provide I&T support and Final Document Preparation | 60w | 2023-01-23 | 2024-03-15 | 240 |  |  |  | 0d |  |  | MarinE_I [20%]; CavedoniC_I [15%]; SchneiderT_I [15%] | 1200h | 117,396 |
| 334 | 1.4.6.2 | **Control Computer Software** | 125d | 2022-10-04 | 2023-03-27 | 14 |  |  |  | 0d |  |  |  | 680h | 62,531.6 |
| 335 | 1.4.6.2.1 | Test LIS Interface for each Laser (Toptica EC to LIS PLC) | 2w | 2022-10-04 | 2022-10-17 |  |  |  |  | 0d |  |  | KarewiczS_I [50%] | 40h | 3,913.2 |
| 336 | 1.4.6.2.2 | Test LIS shuttering sequences with all lasers | 4w | 2022-10-18 | 2022-11-14 | 335 |  |  |  | 0d |  |  | EbbersA_I [50%]; KarewiczS_I [50%] | 160h | 14,958.4 |
| 337 | 1.4.6.2.3 | Test access door interlocks and bypasses. | 1w | 2022-11-15 | 2022-11-21 | 336 |  |  |  | 0d |  |  | EbbersA_I [50%]; KarewiczS_I [50%] | 40h | 3,739.6 |
| 338 | 1.4.6.2.4 | Test all BTO functionality (motors, loops, status, error handling) | 4w | 2022-11-22 | 2022-12-19 | 337 |  |  |  | 0d |  |  | EbbersA_I [50%]; SchneiderT_I [25%] | 120h | 11,045.2 |
| 339 | 1.4.6.2.5 | Test any new features | 2w | 2022-12-20 | 2023-01-02 | 338 |  |  |  | 0d |  |  | EbbersA_I [50%] | 40h | 3,566 |
| 340 | 1.4.6.2.6 | Test LHX | 2w | 2023-01-03 | 2023-01-16 | 339 |  |  |  | 0d |  |  | EbbersA_I [50%]; KarewiczS_I [50%] | 80h | 7,479.2 |
| 341 | 1.4.6.2.7 | Test fast steering mirror (FSM) control | 2w | 2023-01-17 | 2023-01-30 | 340 |  |  |  | 0d |  |  | EbbersA_I [50%] | 40h | 3,566 |
| 342 | 1.4.6.2.8 | Test Laser Control Console | 8w | 2023-01-31 | 2023-03-27 | 341 |  |  |  | 0d |  |  | EbbersA_I [50%] | 160h | 14,264 |
| 344 | 1.5 | **Adaptive Optics Subsystem (AOS) (mostly a subcontract)** | 254w | 2019-05-20 | 2024-03-29 |  | 2006-06-26 | 2010-10-14 | 224.64w? | 0d |  |  |  | 10739.7h | 1,001,914.07 |
| 345 | 1.5.1 | **AOS System Engineering** | 1270d | 2019-05-20 | 2024-03-29 |  |  |  |  | 0d |  |  |  | 5559.74h | 517,280.47 |
| 346 | 1.5.1.1 | **Conceptual Design** | 96d | 2019-05-20 | 2019-09-30 |  |  |  |  | 0d |  |  |  | 1825.74h | 158,751.15 |
| 347 | 1.5.1.1.1 | **AOS Subsystem Requirements Definition** | 86d | 2019-06-03 | 2019-09-30 |  |  |  |  | 0d |  |  |  | 1158.6h | 101,266.21 |
| 348 | 1.5.1.1.1.1 | Generate AOS Top Level Functional Flow Break Down | 5w | 2019-06-03 | 2019-07-05 |  |  |  |  | 0d |  | start no earlier than 2019-06-03 | ProvostN_P [5%]; MontesV_P [25%]; SivoG_P [10%] | 80h | 6,855.5 |
| 349 | 1.5.1.1.1.2 | Flow Top Level Requirements to AOS from top level science Requirements (Second Draft) | 4w | 2019-07-08 | 2019-08-02 | 348 |  |  |  | 0d |  | start no earlier than 2019-06-03 | ProvostN_P [5%]; RamboldW_P [10%]; MontesV_P [20%]; ChirreE_P [10%] | 72h | 6,359.28 |
| 350 | 1.5.1.1.1.3 | Generate AOS Functional Requirements and compare against existing GN and GS LGS requirements (Second Draft) | 1w | 2019-08-05 | 2019-08-09 | 349 |  |  |  | 0d |  | start no earlier than 2019-06-03 | ProvostN_P [5%]; RamboldW_P [10%]; MontesV_P [20%]; ChirreE_P [10%] | 18h | 1,589.82 |
| 351 | 1.5.1.1.1.4 | Update Requirements based on Interface Definition, Conops, Trade Study Results etc, Add rationale | 6w | 2019-08-12 | 2019-09-20 | 350 |  |  |  | 0d |  | start no earlier than 2019-06-03 | ProvostN_P [5%]; MontesV_P [15%] | 48h | 4,222.68 |
| 352 | 1.5.1.1.1.5 | Generate AOS Verification Plan for each Requirement and fill out VCRM | 12w | 2019-06-10 | 2019-08-30 |  |  |  |  | 0d |  | finish no earlier than 2019-08-30 | ProvostN_P [5%]; RamboldW_P [10%]; MontesV_P [20%] | 168h | 14,905.68 |
| 353 | 1.5.1.1.1.6 | Input AOS Requirements and Verification Methods into DOORS | 11w | 2019-06-17 | 2019-08-30 |  |  |  |  | 0d |  | finish no earlier than 2019-08-30 | ProvostN_P [5%]; BassettJ_P [5%] | 44h | 4,009.72 |
| 354 | 1.5.1.1.1.7 | Finalize Export AOS Subsystem Requirements Document with VCRM for CoDR | 4w | 2019-09-03 | 2019-09-30 |  |  |  |  | 0d |  | finish no earlier than 2019-09-30 | ProvostN_P [5%]; BassettJ_P [5%]; RadwickJ_P [10%] | 32h | 2,916.16 |

Notes:
- 332: Finalize And Perform Superstructure Acceptance Tests
- 344: Supervisory / Component-control Computer (SCC) (HIA)

| ID | WBS | Task | Duration | Start | Finish | Predecessors | Total slack | Constraint | Resources | Work | Cost |
| --- | --- | --- | --- | --- | --- | --- | --- | --- | --- | --- | --- |
| 355 | 1.5.1.1.1.8 | **Generate AOS Interface Requirements Definition** | 86d | 2019-06-03 | 2019-09-30 |  | 0d |  |  | 696.6h | 60,407.37 |
| 356 | 1.5.1.1.1.8.1 | Define AOS Functional External Interfaces | 6w | 2019-06-03 | 2019-07-12 |  | 0d | start no earlier than 2019-06-03 | ProvostN_P [10%]; MontesV_P [20%]; ChirreE_P [10%]; EbbersA_P [10%]; ChinnB_P [10%] | 132.6h | 11,459.17 |
| 357 | 1.5.1.1.1.8.2 | Generate AOS Interface Control Document for AOS - RTC First Draft | 4w | 2019-07-15 | 2019-08-09 | 356 | 0d | start no earlier than 2019-06-17 | ProvostN_P [5%]; MontesV_P [5%]; EbbersA_P [20%]; RamboldW_P [20%] | 80h | 6,875.28 |
| 358 | 1.5.1.1.1.8.3 | Generate LGS Interface Control Document for AOS - TLC First Draft | 4w | 2019-07-15 | 2019-08-09 | 356 | 0d | start no earlier than 2019-06-10 | ProvostN_P [5%]; MontesV_P [5%]; EbbersA_P [20%]; RamboldW_P [20%] | 80h | 6,875.28 |
| 359 | 1.5.1.1.1.8.4 | Generate LGS Interface Control Document for AOS -TCC First Draft | 4w | 2019-07-15 | 2019-08-09 | 356 | 0d | start no earlier than 2019-06-10 | ProvostN_P [5%]; MontesV_P [5%]; EbbersA_P [20%]; RamboldW_P [20%] | 80h | 6,875.28 |
| 360 | 1.5.1.1.1.8.5 | Update, Review Electrical Interface Requirements | 4w | 2019-08-12 | 2019-09-06 | 357 | 0d | start no earlier than 2019-07-01 | ProvostN_P [5%]; MontesV_P [10%] | 24h | 2,119.76 |
| 361 | 1.5.1.1.1.8.6 | Update, Review Mechancial Interface Requirements | 4w | 2019-08-12 | 2019-09-06 | 357 | 0d | start no earlier than 2019-07-01 | ProvostN_P [5%]; MontesV_P [5%]; ChinnB_P [15%] | 40h | 3,510.48 |
| 362 | 1.5.1.1.1.8.7 | Update, Review Service Requirements | 4w | 2019-08-12 | 2019-09-06 | 357 | 0d | start no earlier than 2019-07-01 | ProvostN_P [5%]; MontesV_P [5%]; ChinnB_P [15%] | 40h | 3,510.48 |
| 363 | 1.5.1.1.1.8.8 | Update, Review Environmental Requirements | 4w | 2019-08-12 | 2019-09-06 | 357 | 0d | start no earlier than 2019-07-01 | ProvostN_P [5%]; MontesV_P [5%]; ChinnB_P [15%] | 40h | 3,510.48 |
| 364 | 1.5.1.1.1.8.9 | Review, Update, Finalize CoDR Drafts of ICDs | 9w | 2019-07-30 | 2019-09-30 |  | 0d | start no earlier than 2019-07-30 | ProvostN_P [10%]; MontesV_P [10%]; EbbersA_P [10%]; ChinnB_P [10%]; RamboldW_P [10%] | 180h | 15,671.16 |
| 365 | 1.5.1.1.2 | **Generate AOS Concept of Operations** | 55d | 2019-05-20 | 2019-08-02 |  | 0d |  |  | 251.14h | 21,527.82 |
| 366 | 1.5.1.1.2.1 | Describe GeMS System and Reason for Change | 3w | 2019-05-20 | 2019-06-07 |  | 0d | finish no earlier than 2019-06-07 | ProvostN_P [10%]; MontesV_P [30%]; SivoG_P [10%]; ScharwaechterJ_P [5%] | 47.14h | 4,022 |
| 367 | 1.5.1.1.2.2 | Describe GNAO AOS System Operation (1st Draft) | 6w | 2019-06-06 | 2019-07-17 |  | 0d | finish no earlier than 2019-07-17 | ProvostN_P [10%]; MontesV_P [10%]; SivoG_P [10%]; ScharwaechterJ_P [5%] | 84h | 7,149.96 |
| 368 | 1.5.1.1.2.3 | Review, Update AOS Conops, incorporate into GNAO conops | 6.67w | 2019-06-18 | 2019-08-02 |  | 0d | finish no earlier than 2019-08-02 | ProvostN_P [10%]; MontesV_P [10%]; EbbersA_P [10%]; RamboldW_P [10%]; ScharwaechterJ_P [5%] | 120h | 10,355.87 |
| 369 | 1.5.1.1.3 | Lead and participate in design trades | 14w | 2019-06-03 | 2019-09-06 |  | 0d |  | ProvostN_P [10%]; MontesV_P [20%]; SivoG_P [10%] | 224h | 19,313.28 |
| 370 | 1.5.1.1.4 | Generate, review, and provide input on AOS Package | 4w | 2019-09-02 | 2019-09-27 |  | 0d | finish no earlier than 2019-09-27 | ProvostN_P [10%]; MontesV_P [50%]; ChirreE_P [30%]; ChinnB_P [20%]; SivoG_P [10%] | 192h | 16,643.84 |
| 371 | 1.5.1.2 | **Preliminary (subcontract)** | 170d | 2019-10-01 | 2020-05-25 | 5 | 0d |  |  | 272h | 24,787.36 |
| 372 | 1.5.1.2.1 | provide SE oversight | 34w | 2019-10-01 | 2020-05-25 |  | 0d |  | ProvostN_P [20%] | 272h | 24,787.36 |
| 373 | 1.5.1.3 | **Critical Design (subcontract)** | 170d | 2020-06-01 | 2021-01-22 | 8 | 0d |  |  | 272h | 25,529.92 |
| 374 | 1.5.1.3.1 | provide SE oversight | 34w | 2020-06-01 | 2021-01-22 |  | 0d |  | ProvostN_C [20%] | 272h | 25,529.92 |
| 375 | 1.5.1.4 | **Build (subcontract)** | 436d | 2021-02-01 | 2022-10-03 | 11 | 0d |  |  | 880h | 84,650.24 |
| 376 | 1.5.1.4.1 | provide SE oversight | 86w | 2021-02-01 | 2022-09-23 |  | 0d |  | ProvostN_B [20%] | 688h | 66,515.84 |
| 377 | 1.5.1.4.2 | **AOS Verification** | 60d | 2022-07-12 | 2022-10-03 | 14FS-12w | 0d |  |  | 192h | 18,134.4 |
| 378 | 1.5.1.4.2.1 | Review Vendor's AOS Acceptance Test Plan | 8w | 2022-07-12 | 2022-09-05 |  | 0d |  | ProvostN_B [20%]; MontesV_B [20%] | 128h | 12,089.6 |
| 379 | 1.5.1.4.2.2 | Review and Approve Acceptance Test results | 4w | 2022-09-06 | 2022-10-03 | 378 | 0d |  | ProvostN_B [20%]; MontesV_B [20%] | 64h | 6,044.8 |

| ID | WBS | Task | Duration | Start | Finish | Predecessors | Baseline start | Baseline finish | Baseline duration | Total slack | Constraint | Resources | Work | Cost |
| --- | --- | --- | --- | --- | --- | --- | --- | --- | --- | --- | --- | --- | --- | --- |
| 380 | 1.5.1.5 | **Integration and Testing (I&T)** | 385d | 2022-10-10 | 2024-03-29 | 14 |  |  |  | 0d |  |  | 2310h | 223,561.8 |
| 381 | 1.5.1.5.1 | Lead AOS Integration and Test in conjunction with the AOS subcontractor, including development of integration test plan, implementing plan, lead anomaly resolution, lead interface management, Perform tests, review and document results | 77w | 2022-10-10 | 2024-03-29 |  |  |  |  | 0d | finish no earlier than 2024-03-29 | ProvostN_I [25%]; MontesV_I [25%]; SivoG_I [25%] | 2310h | 223,561.8 |
| 382 | 1.5.2 | **Conceptual Design** | 85d | 2019-06-03 | 2019-09-27 |  |  |  |  | 0d |  |  | 660h | 57,367.2 |
| 383 | 1.5.2.1 | **Optical Engineering** | 80d | 2019-06-03 | 2019-09-20 |  |  |  |  | 0d |  |  | 320h | 27,814.4 |
| 384 | 1.5.2.1.1 | refine conceptual optical design including layout of the AOB, optical elements, and coatings | 6w | 2019-06-03 | 2019-07-12 |  |  |  |  | 0d |  | ChirreE_P [50%] | 120h | 10,430.4 |
| 385 | 1.5.2.1.2 | perform preliminary tolerancing analysis | 3w | 2019-07-15 | 2019-08-02 | 384 |  |  |  | 0d |  | ChirreE_P [50%] | 60h | 5,215.2 |
| 386 | 1.5.2.1.3 | perform preliminary throughput analysis | 2w | 2019-08-05 | 2019-08-16 | 385 |  |  |  | 0d |  | ChirreE_P [50%] | 40h | 3,476.8 |
| 387 | 1.5.2.1.4 | assess risks in the conceptual optical design | 3w | 2019-08-19 | 2019-09-06 | 386 |  |  |  | 0d |  | ChirreE_P [50%] | 60h | 5,215.2 |
| 388 | 1.5.2.1.5 | documentation preparation | 2w | 2019-09-09 | 2019-09-20 | 387 |  |  |  | 0d |  | ChirreE_P [50%] | 40h | 3,476.8 |
| 389 | 1.5.2.2 | **Mechanical Engineering** | 85d | 2019-06-03 | 2019-09-27 |  |  |  |  | 0d |  |  | 340h | 29,552.8 |
| 390 | 1.5.2.2.1 | refine conceptual mechanical design including structural, science path, LGSWFS, and NGSWFS | 6w | 2019-06-03 | 2019-07-12 |  |  |  |  | 0d |  | ChinnB_P [50%] | 120h | 10,430.4 |
| 391 | 1.5.2.2.2 | preliminary thermal and flexure studies | 5w | 2019-07-15 | 2019-08-16 | 390 |  |  |  | 0d |  | ChinnB_P [50%] | 100h | 8,692 |
| 392 | 1.5.2.2.3 | preliminary optomechanical tolerancing analysis | 4w | 2019-08-19 | 2019-09-13 | 391 |  |  |  | 0d |  | ChinnB_P [50%] | 80h | 6,953.6 |
| 393 | 1.5.2.2.4 | documentation preparation | 2w | 2019-09-16 | 2019-09-27 | 392 |  |  |  | 0d |  | ChinnB_P [50%] | 40h | 3,476.8 |
| 394 | 1.5.3 | **Preliminary Design** | 120d | 2019-10-01 | 2020-03-16 | 5 | 2006-06-26 | 2007-05-09 | 45.51w? | 0d |  |  | 960h | 87,484.8 |
| 395 | 1.5.3.1 | **Control Computer Software** | 120d | 2019-10-01 | 2020-03-16 |  |  |  |  | 0d |  |  | 960h | 87,484.8 |
| 396 | 1.5.3.1.1 | Adaptive Optics Subsystem Components Controller Design | 8w | 2019-10-01 | 2019-11-25 |  |  |  |  | 0d |  | SE1_P | 320h | 29,161.6 |
| 397 | 1.5.3.1.2 | Instrument Sequencer Design | 8w | 2019-11-26 | 2020-01-20 | 396 |  |  |  | 0d |  | SE1_P | 320h | 29,161.6 |
| 398 | 1.5.3.1.3 | Graphical User Interface Design | 8w | 2020-01-21 | 2020-03-16 | 397 |  |  |  | 0d |  | SE1_P | 320h | 29,161.6 |
| 399 | 1.5.4 | **Critical Design** | 385d | 2020-06-01 | 2021-11-19 | 8 | 2007-06-01 | 2008-06-06 | 53.09w? | 0d |  |  | 3080h | 293,375.2 |
| 400 | 1.5.4.1 | **Control Computer Software** | 385d | 2020-06-01 | 2021-11-19 |  |  |  |  | 0d |  |  | 3080h | 293,375.2 |
| 401 | 1.5.4.1.1 | Implement AOS Components Controller | 16w | 2020-06-01 | 2020-09-18 |  |  |  |  | 0d |  | SE1_C | 640h | 60,070.4 |
| 402 | 1.5.4.1.2 | Implement Instrument Sequencer | 4w | 2020-09-21 | 2020-10-16 | 401 |  |  |  | 0d |  | SE1_C | 160h | 15,017.6 |
| 403 | 1.5.4.1.3 | **Implement Graphical User Interface** | 170d | 2020-10-19 | 2021-06-11 |  |  |  |  | 0d |  |  | 1360h | 129,341.6 |
| 404 | 1.5.4.1.3.1 | Infrastructure | 1w | 2020-10-19 | 2020-10-23 | 402 |  |  |  | 0d |  | SE1_C | 40h | 3,754.4 |
| 405 | 1.5.4.1.3.2 | AOS Components Controller | 4w | 2020-10-26 | 2020-11-20 | 404 |  |  |  | 0d |  | SE1_C | 160h | 15,017.6 |
| 406 | 1.5.4.1.3.3 | LGSF Components Controller | 2w | 2020-11-23 | 2020-12-04 | 405 |  |  |  | 0d |  | SE1_C | 80h | 7,508.8 |
| 407 | 1.5.4.1.3.4 | Loop Control | 2w | 2020-12-07 | 2020-12-18 | 406 |  |  |  | 0d |  | SE1_C | 80h | 7,508.8 |
| 408 | 1.5.4.1.3.5 | Telemetry Display | 10w | 2020-12-21 | 2021-02-26 | 407 |  |  |  | 0d |  | SE1_C | 400h | 37,544 |
| 409 | 1.5.4.1.3.6 | NGS Configuration | 2w | 2021-03-01 | 2021-03-12 | 408 |  |  |  | 0d |  | SE1_B | 80h | 7,734.4 |
| 410 | 1.5.4.1.3.7 | Instrument Sequencer display and control | 1w | 2021-03-15 | 2021-03-19 | 409 |  |  |  | 0d |  | SE1_B | 40h | 3,867.2 |
| 411 | 1.5.4.1.3.8 | Calibration | 4w | 2021-03-22 | 2021-04-16 | 410 |  |  |  | 0d |  | SE1_B | 160h | 15,468.8 |
| 412 | 1.5.4.1.3.9 | Misc. screens | 8w | 2021-04-19 | 2021-06-11 | 411 |  |  |  | 0d |  | SE1_B | 320h | 30,937.6 |
| 413 | 1.5.4.1.4 | Implement GIAPI interfaces | 4w | 2021-06-14 | 2021-07-09 | 412 |  |  |  | 0d |  | SE1_B | 160h | 15,468.8 |
| 414 | 1.5.4.1.5 | Implement Safety Interlocks | 2w | 2021-07-12 | 2021-07-23 | 413 |  |  |  | 0d |  | SE1_B | 80h | 7,734.4 |
| 415 | 1.5.4.1.6 | Telemetry storage and access control | 17w | 2021-07-26 | 2021-11-19 | 414 |  |  |  | 0d |  | SE1_B | 680h | 65,742.4 |

Notes:
- 394: Preliminary Design
- 399: Critical Design

| ID | WBS | Task | Duration | Start | Finish | Predecessors | Baseline start | Baseline finish | Baseline duration | Total slack | Resources | Work | Cost |
| --- | --- | --- | --- | --- | --- | --- | --- | --- | --- | --- | --- | --- | --- |
| 416 | 1.5.5 | **Build / Implement / Incrementally Integrate & Test** | 40d | 2021-11-22 | 2022-01-14 | 399 | 2008-06-10 | 2009-09-18 | 66.67w | 0d |  | 480h | 46,406.4 |
| 417 | 1.5.5.1 | Control Computer Software Testing of Mechanical Components | 8w | 2021-11-22 | 2022-01-14 |  |  |  |  | 0d | SE1_B | 320h | 30,937.6 |
| 418 | 1.5.5.2 | Finalize And Perform Acceptance Tests | 4w | 2021-11-22 | 2021-12-17 |  | 2009-09-21 | 2009-12-29 | 14.14w? | 0d | SE1_B | 160h | 15,468.8 |
| 420 | 1.6 | **Real-Time Computer (RTC)** | 1274.33d? | 2019-06-03 | 2024-04-19 |  |  |  |  | 0d |  | 10828h | 875,260.09 |
| 421 | 1.6.1 | **RTC Systems Engineering** | 80d | 2019-06-03 | 2019-09-20 |  |  |  |  | 0d |  | 476h | 40,394.92 |
| 422 | 1.6.1.1 | flow-down GNAO / GeMS system requirements to the RTC and generate RTC Functional Requirements and compare against existing GN and GS LGS requirements. | 6w | 2019-06-03 | 2019-07-12 |  |  |  |  | 0d | HirstP_P [10%]; PalmerD_P [10%]; ProvostN_P [10%]; RamboldW_P [10%]; SivoG_P [10%] | 120h | 12,281.52 |
| 423 | 1.6.1.2 | write a draft of the final test document to assure that the requirements can be tested against. | 4w | 2019-07-15 | 2019-08-09 | 422 |  |  |  | 0d | JenkinsD_P [50%] | 80h | 4,374.4 |
| 424 | 1.6.1.3 | design external RTC interfaces and generate ICDs. | 2w | 2019-08-12 | 2019-08-23 | 423 |  |  |  | 0d | RamboldW_P [25%]; HirstP_P [20%]; PalmerD_P [20%]; SivoG_P [10%]; JenkinsD_P [50%] | 100h | 8,642.04 |
| 425 | 1.6.1.4 | start a Design Document and Users Manual to serve as input to the CoDR documentation package (and to be kept up to date as the project progresses). | 4w | 2019-08-26 | 2019-09-20 | 424 |  |  |  | 0d | RamboldW_P [10%]; HirstP_P [20%]; PalmerD_P [20%]; SivoG_P [10%]; JenkinsD_P [50%] | 176h | 15,096.96 |
| 426 | 1.6.2 | **Select computer hardware (for GeMS) and a software package; then procure it and bring it up (this is to serve as development/test platform)** | 117d? | 2019-09-23 | 2020-03-03 |  |  |  |  | 0d |  | 864h | 71,581.6 |
| 427 | 1.6.2.1 | select an existing AO RTC software package to serve as the baseline for RTC software development | 4w | 2019-09-23 | 2019-10-18 | 425 |  |  |  | 0d | HirstP_P [20%]; PalmerD_P [20%]; RamboldW_P [25%]; SivoG_P [10%]; JenkinsD_P [25%] | 160h | 15,096.88 |
| 428 | 1.6.2.2 | participate in AO RTC package training (this is a training place holder) | 1w | 2019-10-21 | 2019-10-25 | 427 |  |  |  | 0d | PalmerD_P; RamboldW_P; JenkinsD_P | 120h | 10,823.6 |
| 429 | 1.6.2.3 | analyze the requirements for and select AO peripheral interfaces for GeMS | 6w | 2019-10-28 | 2019-12-06 | 428 |  |  |  | 0d | HirstP_P [10%]; PalmerD_P [10%]; RamboldW_P [40%]; JenkinsD_P [50%] | 264h | 21,299.52 |
| 430 | 1.6.2.4 | analyze the requirements for and select/configure a computer platform for GeMS, including OS | 4w | 2019-10-28 | 2019-11-22 | 428 |  |  |  | 10d | HirstP_P [5%]; PalmerD_P [5%]; RamboldW_P [10%] | 32h | 3,454.56 |
| 431 | 1.6.2.5 | hold a special review of the software package and hardware selections. | 0.4w | 2019-12-09 | 2019-12-10 | 427, 429, 430 |  |  |  | 0d | HirstP_P; PalmerD_P; RamboldW_P; JenkinsD_P | 64h | 6,325.92 |
| 432 | 1.6.2.6 | procure software package, including support as required | 4w | 2019-12-11 | 2020-01-07 | 431 |  |  |  | 0d | RamboldW_P [10%] | 16h | 1,458.08 |
| 433 | 1.6.2.7 | procure the AO peripheral interfaces for GeMS | 8w | 2019-12-11 | 2020-02-04 | 431 |  |  |  | 0d | RamboldW_P [10%] | 32h | 2,916.16 |
| 434 | 1.6.2.8 | procure the computer platform for GeMS | 4w | 2019-12-11 | 2020-01-07 | 431 |  |  |  | 0d | RamboldW_P [10%] | 16h | 1,458.08 |
| 435 | 1.6.2.9 | bring up the GeMS hardware platform and optimize for performance | 4w? | 2020-01-08 | 2020-02-04 | 434 |  |  |  | 0d | JenkinsD_P [50%] | 80h | 4,374.4 |
| 436 | 1.6.2.10 | install drivers for GeMS AO peripherals and test, as hardware becomes available | 4w? | 2020-02-05 | 2020-03-03 | 435 |  |  |  | 0d | JenkinsD_P [50%] | 80h | 4,374.4 |
| 437 | 1.6.3 | **Design the adaptation of the AO RTC package to GeMS and design new code as needed. This is the design phase for RTC software.** | 137.33d | 2019-12-11 | 2020-06-19 |  |  |  |  | 0d |  | 1648h | 129,389.97 |
| 438 | 1.6.3.1 | adapt AO RTC package infrastructure to GeMS/GNAO needs | 1.6w | 2019-12-11 | 2019-12-20 | 431 |  |  |  | 0d | JenkinsD_P [75%]; PalmerD_P [25%]; RamboldW_P [50%] | 96h | 7,537.28 |
| 439 | 1.6.3.2 | TLC interface software | 1.6w | 2019-12-23 | 2020-01-01 | 438 |  |  |  | 0d | JenkinsD_P [75%]; PalmerD_P [25%]; RamboldW_P [50%] | 96h | 7,537.28 |
| 440 | 1.6.3.3 | NGS camera interface software (the 'Design' work for this is higher than normal, wrt 'Implementation', to accommodate GeMS legacy hardware) | 2.67w | 2020-01-02 | 2020-01-21 | 439 |  |  |  | 0d | JenkinsD_P [75%]; PalmerD_P [25%]; RamboldW_P [50%] | 160h | 12,562.13 |
| 441 | 1.6.3.4 | NGS tip/tilt computation | 0.8w | 2020-01-21 | 2020-01-27 | 440 |  |  |  | 0d | JenkinsD_P [75%]; PalmerD_P [25%]; RamboldW_P [50%] | 48h | 3,768.64 |
| 442 | 1.6.3.5 | TT interface software | 0.8w | 2020-01-27 | 2020-01-31 | 441 |  |  |  | 0d | JenkinsD_P [75%]; PalmerD_P [25%]; RamboldW_P [50%] | 48h | 3,768.64 |
| 443 | 1.6.3.6 | LGS cameras interface software (the 'Design' work for this is higher than normal, wrt 'Implementation', to accommodate GeMS legacy hardware) | 2.67w | 2020-01-31 | 2020-02-19 | 442 |  |  |  | 0d | JenkinsD_P [75%]; PalmerD_P [25%]; RamboldW_P [50%] | 160h | 12,562.13 |
| 444 | 1.6.3.7 | centroider | 0.8w | 2020-02-19 | 2020-02-25 | 443 |  |  |  | 0d | JenkinsD_P [75%]; PalmerD_P [25%]; RamboldW_P [50%] | 48h | 3,768.64 |
| 445 | 1.6.3.8 | reconstructor | 2.4w | 2020-02-25 | 2020-03-12 | 444 |  |  |  | 0d | JenkinsD_P [75%]; PalmerD_P [25%]; RamboldW_P [50%] | 144h | 11,305.92 |
| 446 | 1.6.3.9 | DMs interface software (the 'Design' work for this is higher than normal, wrt 'Implementation', to accommodate GeMS legacy hardware) | 2.67w | 2020-03-12 | 2020-03-31 | 445 |  |  |  | 0d | JenkinsD_P [75%]; PalmerD_P [25%]; RamboldW_P [50%] | 160h | 12,562.13 |
| 447 | 1.6.3.10 | slow focus detector software | 0.8w | 2020-04-01 | 2020-04-06 | 446 |  |  |  | 0d | JenkinsD_P [75%]; PalmerD_P [25%]; RamboldW_P [50%] | 48h | 3,768.64 |
| 448 | 1.6.3.11 | slow focus computation | 0.8w | 2020-04-07 | 2020-04-10 | 447 |  |  |  | 0d | JenkinsD_P [75%]; PalmerD_P [25%]; RamboldW_P [50%] | 48h | 3,768.64 |
| 449 | 1.6.3.12 | LGS zoom interface software (for slow focus) (the 'Design' work for this is higher than normal, wrt 'Implementation', to accommodate GeMS legacy hardware) | 2.67w | 2020-04-13 | 2020-04-30 | 448 |  |  |  | 0d | JenkinsD_P [75%]; PalmerD_P [25%]; RamboldW_P [50%] | 160h | 12,562.13 |
| 450 | 1.6.3.13 | telescope offload and LGS pointing control software | 0.8w | 2020-04-30 | 2020-05-06 | 449 |  |  |  | 0d | JenkinsD_P [75%]; PalmerD_P [25%]; RamboldW_P [50%] | 48h | 3,768.64 |
| 451 | 1.6.3.14 | telemetry date streaming/archiving software | 2.4w | 2020-05-06 | 2020-05-22 | 450 |  |  |  | 0d | JenkinsD_P [75%]; PalmerD_P [25%]; RamboldW_P [50%] | 144h | 11,305.92 |
| 452 | 1.6.3.15 | telemetry data display software | 1.6w | 2020-05-22 | 2020-06-03 | 451 |  |  |  | 0d | JenkinsD_P [75%]; PalmerD_P [25%]; RamboldW_P [50%] | 96h | 7,537.28 |
| 453 | 1.6.3.16 | investigate PSF reconstruction | 0.8w | 2020-06-03 | 2020-06-09 | 452 |  |  |  | 0d | JenkinsD_P [75%]; PalmerD_P [25%]; RamboldW_P [50%] | 48h | 3,768.64 |
| 454 | 1.6.3.17 | reconstructor matrix generation | 1.6w | 2020-06-09 | 2020-06-19 | 453 |  |  |  | 0d | JenkinsD_P [75%]; PalmerD_P [25%]; RamboldW_P [50%] | 96h | 7,537.28 |

Notes:
- 416: Build / Implement / Incrementally Integrate & Test
- 418: Finalize And Perform Superstructure Acceptance Tests

| ID | WBS | Task | Type | Duration | Start | Finish | Predecessors | Total slack | Resources | Work | Cost |
| --- | --- | --- | --- | --- | --- | --- | --- | --- | --- | --- | --- |
| 455 | 1.6.4 | **Implement and test code to provide GeMS functionality as designed in the previous set of tasks. This is the implementation and testing phase for the RTC software (not to be confused with Integration and Test).** |  | 300d | 2020-06-19 | 2021-08-13 |  | 0d |  | 3600h | 295,199.6 |
| 456 | 1.6.4.1 | adapt DARC infrastructure to GeMS/GNAO needs |  | 1.6w | 2020-06-19 | 2020-07-01 | 8, 454 | 0d | JenkinsD_C [75%]; PalmerD_C [25%]; RamboldW_C [50%] | 96h | 7,763.2 |
| 457 | 1.6.4.2 | TLC interface software |  | 6.4w | 2020-07-01 | 2020-08-14 | 456 | 0d | JenkinsD_C [75%]; PalmerD_C [25%]; RamboldW_C [50%] | 384h | 31,052.8 |
| 458 | 1.6.4.3 | NGS camera interface software |  | 1.6w | 2020-08-14 | 2020-08-26 | 457 | 0d | JenkinsD_C [75%]; PalmerD_C [25%]; RamboldW_C [50%] | 96h | 7,763.2 |
| 459 | 1.6.4.4 | NGS tip/tilt computation |  | 4.8w | 2020-08-26 | 2020-09-29 | 458 | 0d | JenkinsD_C [75%]; PalmerD_C [25%]; RamboldW_C [50%] | 288h | 23,289.6 |
| 460 | 1.6.4.5 | TT interface software |  | 1.6w | 2020-09-29 | 2020-10-09 | 459 | 0d | JenkinsD_C [75%]; PalmerD_C [25%]; RamboldW_C [50%] | 96h | 7,763.2 |
| 461 | 1.6.4.6 | LGS cameras interface software |  | 1.6w | 2020-10-09 | 2020-10-21 | 460 | 0d | JenkinsD_C [75%]; PalmerD_C [25%]; RamboldW_C [50%] | 96h | 7,763.2 |
| 462 | 1.6.4.7 | centroider |  | 2.4w | 2020-10-21 | 2020-11-06 | 461 | 0d | JenkinsD_C [75%]; PalmerD_C [25%]; RamboldW_C [50%] | 144h | 11,644.8 |
| 463 | 1.6.4.8 | reconstructor |  | 10.4w | 2020-11-06 | 2021-01-19 | 462 | 0d | JenkinsD_C [75%]; PalmerD_C [25%]; RamboldW_C [50%] | 624h | 50,460.8 |
| 464 | 1.6.4.9 | DMs interface software |  | 1.6w | 2021-01-19 | 2021-01-29 | 463 | 0d | JenkinsD_C [75%]; PalmerD_C [25%]; RamboldW_C [50%] | 96h | 7,763.2 |
| 465 | 1.6.4.10 | slow focus detector software |  | 1.6w | 2021-01-29 | 2021-02-10 | 464 | 0d | JenkinsD_B [75%]; PalmerD_B [25%]; RamboldW_B [50%] | 96h | 7,996.32 |
| 466 | 1.6.4.11 | slow focus computation |  | 2.4w | 2021-02-10 | 2021-02-26 | 465 | 0d | JenkinsD_B [75%]; PalmerD_B [25%]; RamboldW_B [50%] | 144h | 11,994.48 |
| 467 | 1.6.4.12 | LGS zoom interface software (for slow focus) |  | 1.6w | 2021-02-26 | 2021-03-10 | 466 | 0d | JenkinsD_B [75%]; PalmerD_B [25%]; RamboldW_B [50%] | 96h | 7,996.32 |
| 468 | 1.6.4.13 | telescope offload and LGS pointing control software |  | 2.4w | 2021-03-10 | 2021-03-26 | 467 | 0d | JenkinsD_B [75%]; PalmerD_B [25%]; RamboldW_B [50%] | 144h | 11,994.48 |
| 469 | 1.6.4.14 | telemetry date streaming/archiving software |  | 6.4w | 2021-03-26 | 2021-05-11 | 468 | 0d | JenkinsD_B [75%]; PalmerD_B [25%]; RamboldW_B [50%] | 384h | 31,985.28 |
| 470 | 1.6.4.15 | telemetry data display software |  | 6.4w | 2021-05-11 | 2021-06-24 | 469 | 0d | JenkinsD_B [75%]; PalmerD_B [25%]; RamboldW_B [50%] | 384h | 31,985.28 |
| 471 | 1.6.4.16 | investigate PSF reconstruction |  | 2.4w | 2021-06-24 | 2021-07-12 | 470 | 0d | JenkinsD_B [75%]; PalmerD_B [25%]; RamboldW_B [50%] | 144h | 11,994.48 |
| 472 | 1.6.4.17 | reconstructor matrix generation |  | 4.8w | 2021-07-12 | 2021-08-13 | 471 | 0d | JenkinsD_B [75%]; PalmerD_B [25%]; RamboldW_B [50%] | 288h | 23,988.96 |
| 473 | 1.6.5 | **Perform final testing, integration, and first-light for new GeMS RTC** |  | 40d | 2021-08-13 | 2021-10-08 |  | 0d |  | 480h | 39,981.6 |
| 474 | 1.6.5.1 | finalize the final test document and execute it |  | 3.2w | 2021-08-13 | 2021-09-06 | 472 | 0d | JenkinsD_B [75%]; PalmerD_B [25%]; RamboldW_B [50%] | 192h | 15,992.64 |
| 475 | 1.6.5.2 | finalize all documentation and release |  | 3.2w | 2021-09-06 | 2021-09-28 | 474 | 0d | JenkinsD_B [75%]; PalmerD_B [25%]; RamboldW_B [50%] | 192h | 15,992.64 |
| 476 | 1.6.5.3 | support GeMS integration and first-light (with the new RTC) |  | 1.6w | 2021-09-28 | 2021-10-08 | 475 | 0d | JenkinsD_B [75%]; PalmerD_B [25%]; RamboldW_B [50%] | 96h | 7,996.32 |
| 477 | 1.6.6 | Procure the hardware for GNAO and port the RTC, as developed above, to GNAO. |  | 28w | 2021-10-08 | 2022-04-22 | 476 | 0d | JenkinsD_B [75%]; PalmerD_B [25%]; RamboldW_B [50%] | 1680h | 139,935.6 |
| 478 | 1.6.7 | Provide ongoing support through build and integration |  | 104w | 2022-04-22 | 2024-04-19 | 477 | 0d | JenkinsD_I [25%]; RamboldW_P [25%] | 2080h | 158,776.8 |
| 481 | 1.7 | Overall project Preliminary Design |  | 34.8w | 2019-10-01 | 2020-05-29 | 5 | 0d |  |  |  |
| 482 | 1.8 | Overall project Critical Design |  | 35w | 2020-06-01 | 2021-01-29 | 8 | 0d |  |  |  |
| 483 | 1.9 | Overall project Build |  | 87.2w | 2021-02-01 | 2022-10-03 | 11 | 0d |  |  |  |
| 484 | 1.10 | Overall project I&T |  | 77.8w | 2022-10-04 | 2024-03-29 | 14 | 0d |  |  |  |
| 485 | 1.11 | AOS Preliminary Design |  | 34.8w | 2019-10-01 | 2020-05-29 | 5 | 0d |  |  |  |
| 486 | 1.12 | LGS PD concludes | milestone | 0.2w | 2020-05-28 | 2020-05-29 | 178 | 0d |  |  |  |
| 487 | 1.13 | AOS Critical Design |  | 35w | 2020-06-01 | 2021-01-29 | 8 | 0d |  |  |  |
| 488 | 1.14 | RTC design complete | milestone | 0.2w | 2020-06-19 | 2020-06-22 | 437 | 0d |  |  |  |
| 489 | 1.15 | LGS CD concludes | milestone | 0.2w | 2021-01-28 | 2021-01-29 | 209 | 0d |  |  |  |
| 490 | 1.16 | RTC -- GeMS RTC deployed | milestone | 0.2w | 2021-10-08 | 2021-10-11 | 476 | 0d |  |  |  |
| 491 | 1.17 | AOS control computer ready for integration | milestone | 0.2w | 2022-01-17 | 2022-01-17 | 417 | 0d |  |  |  |
| 492 | 1.18 | RTC -- GNAO RTC ready for integration | milestone | 0.2w | 2022-04-22 | 2022-04-25 | 477 | 0d |  |  |  |
| 493 | 1.19 | LGS laser system 1 installed and commissioned | milestone | 0.2w | 2022-07-22 | 2022-07-22 | 290 | 0d |  |  |  |
| 494 | 1.20 | AOS Build |  | 87.2w | 2021-02-01 | 2022-10-03 | 11 | 0d |  |  |  |
| 495 | 1.21 | LGS laser system 2 installed and commissioned | milestone | 0.2w | 2022-10-24 | 2022-10-24 | 301 | 0d |  |  |  |
| 496 | 1.22 | LGS control computer tested and ready | milestone | 0.2w | 2023-03-28 | 2023-03-28 | 342 | 0d |  |  |  |
| 497 | 1.23 | AOS I&T |  | 77.8w | 2022-10-04 | 2024-03-29 | 14 | 0d |  |  |  |
| 498 | 1.24 | First Light | milestone | 0.2w | 2024-04-01 | 2024-04-01 | 497 | 0d |  |  |  |
