# PIO MS Project file

Schedule from MS Project, 2018-11-27 to 2021-12-31, A marks actual dates.
Gemini Observatory

## Calendars

- Standard: Mon-Fri 08:00-12:00, 13:00-17:00; Sat-Sun off.

## Resources

| Resource |
| --- |
| Peter Michaud - Project Manager |
| Janice Harvey - Project Coordinator |
| Xiaoyu Zhang - PIO Support |
| Manuel Paredes - PIO Support |
| Joy Pollard - PIO Support |
| Alyssa Grace - PIO Support |
| Intern #1 |
| Intern #2 |
| Intern #3 |
| Intern #4 |
| Project Scientist |

## Schedule

| ID | WBS | Task | Type | Duration | Start | Finish | Complete | Remaining | Total slack | Resources | Work | Actual work |
| --- | --- | --- | --- | --- | --- | --- | --- | --- | --- | --- | --- | --- |
| 1 | 5 | **GEMMA PUBLIC INFORMATION AND OUTREACH** |  | 809d | 2018-11-27 A | 2021-12-31 | 2% | 789.49d | 0d |  | 7912.29h | 37h |
| 2 | 5.1 | Project Management | manual | 809d | 2018-11-27 | 2021-12-31 |  |  |  | Peter Michaud - Project Manager; Janice Harvey - Project Coordinator; Project Scientist | 645.8h |  |
| 3 | 5.2 | **MMA-TDA Communications Summit (MTCS)** |  | 260d | 2019-01-01 A | 2019-12-30 | 12% | 228.18d | 0d |  | 954h | 37h |
| 4 | 5.2.1 | Venue selection | manual | 94d | 2019-01-01 A | 2019-05-10 A | 100% |  |  | Peter Michaud - Project Manager; Janice Harvey - Project Coordinator | 37h | 37h |
| 5 | 5.2.2 | Development of MTCS key objectives and outcomes | milestone, manual | 150d | 2019-02-04 | 2019-08-30 |  |  |  | Peter Michaud - Project Manager; Janice Harvey - Project Coordinator | 60h |  |
| 6 | 5.2.3 | Attendees selection and confirmation | manual | 105d | 2019-02-04 | 2019-06-28 |  |  |  | Peter Michaud - Project Manager; Janice Harvey - Project Coordinator | 103h |  |
| 7 | 5.2.4 | Attendees Logistics | manual | 95d | 2019-07-01 | 2019-11-08 |  |  |  | Peter Michaud - Project Manager; Janice Harvey - Project Coordinator | 66h |  |
| 8 | 5.2.5 | Facilitator recruitment | manual | 65d | 2019-04-22 | 2019-07-19 |  |  |  | Peter Michaud - Project Manager; Janice Harvey - Project Coordinator | 82h |  |
| 9 | 5.2.6 | MTCS Material and Content development | manual | 75d | 2019-07-22 | 2019-11-01 |  |  |  | Peter Michaud - Project Manager; Janice Harvey - Project Coordinator | 180h |  |
| 10 | 5.2.7 | MTCS event facility logistics | manual | 115d | 2019-06-03 | 2019-11-08 |  |  |  | Peter Michaud - Project Manager; Janice Harvey - Project Coordinator | 232h |  |
| 11 | 5.2.8 | MTCS Execution | milestone, manual | 7d | 2019-11-02 | 2019-11-09 |  |  |  | Peter Michaud - Project Manager; Janice Harvey - Project Coordinator | 120h |  |
| 12 | 5.2.9 | MTCS Culmination Dinner | manual | 26d | 2019-10-04 | 2019-11-08 |  |  |  | Peter Michaud - Project Manager; Janice Harvey - Project Coordinator | 8h |  |
| 13 | 5.2.10 | MTCS close-out | manual | 36d | 2019-11-11 | 2019-12-30 |  |  |  | Peter Michaud - Project Manager; Janice Harvey - Project Coordinator | 66h |  |
| 14 | 5.3 | **MMA-TDA Media Workshop (MTMW)** |  | 190d | 2020-04-20 | 2021-01-10 |  |  | 0d |  | 361h |  |
| 15 | 5.3.1 | MTMW key objectives, outcomes | milestone, manual | 16d | 2020-04-20 | 2020-05-10 |  |  |  | Peter Michaud - Project Manager; Janice Harvey - Project Coordinator | 35h |  |
| 16 | 5.3.2 | Submit 2021 AAS MTMW proposal and receive acceptance | manual | 33d | 2020-05-15 | 2020-06-30 |  |  |  | Peter Michaud - Project Manager; Janice Harvey - Project Coordinator | 6h |  |
| 17 | 5.3.3 | MTMW Facility rental agreement | manual | 16d | 2020-10-09 | 2020-10-30 |  |  |  | Peter Michaud - Project Manager; Janice Harvey - Project Coordinator | 17h |  |
| 18 | 5.3.4 | Workshop presentors selection and confirmation | manual | 66d | 2020-06-01 | 2020-08-30 |  |  |  | Peter Michaud - Project Manager; Janice Harvey - Project Coordinator | 90h |  |
| 19 | 5.3.5 | MTMW presentors and staff logistics | manual | 23d | 2020-10-01 | 2020-10-31 |  |  |  | Peter Michaud - Project Manager; Janice Harvey - Project Coordinator | 53h |  |
| 20 | 5.3.6 | MTMW content preparation and promotion | manual | 110d | 2020-08-01 | 2020-12-31 |  |  |  | Peter Michaud - Project Manager; Janice Harvey - Project Coordinator; Xiaoyu Zhang - PIO Support | 30h |  |
| 21 | 5.3.7 | Finalize MTMW Agenda | manual | 32d | 2020-11-01 | 2020-12-13 |  |  |  | Peter Michaud - Project Manager; Janice Harvey - Project Coordinator; Xiaoyu Zhang - PIO Support | 50h |  |
| 22 | 5.3.8 | Workshop execution | milestone, manual | 7d | 2021-01-02 | 2021-01-10 |  |  |  | Peter Michaud - Project Manager; Janice Harvey - Project Coordinator | 80h |  |
| 23 | 5.4 | **Staff Media Training** |  | 217d | 2021-02-01 | 2021-11-30 |  |  | 0d |  | 212h |  |
| 24 | 5.4.1 | Training objectives, outcomes, and scope | milestone, manual | 21d | 2021-02-01 | 2021-02-28 |  |  |  | Peter Michaud - Project Manager; Janice Harvey - Project Coordinator | 16h |  |
| 25 | 5.4.2 | Media trainers selection and confirmation (Hawaii/Chile), including training dates | manual | 88d | 2021-03-01 | 2021-06-30 |  |  |  | Peter Michaud - Project Manager; Janice Harvey - Project Coordinator; Manuel Paredes - PIO Support | 69h |  |
| 26 | 5.4.3 | Trainer Logistics | manual | 15d | 2021-07-05 | 2021-07-23 |  |  |  | Peter Michaud - Project Manager; Janice Harvey - Project Coordinator; Manuel Paredes - PIO Support | 18h |  |
| 27 | 5.4.4 | Training attendees selection and confirmation (Gemini/AURA centers) | manual | 66d | 2021-07-01 | 2021-09-30 |  |  |  | Peter Michaud - Project Manager; Janice Harvey - Project Coordinator; Manuel Paredes - PIO Support | 30h |  |
| 28 | 5.4.5 | Training content/focus definition | manual | 27d | 2021-07-30 | 2021-09-06 |  |  |  | Peter Michaud - Project Manager; Janice Harvey - Project Coordinator; Manuel Paredes - PIO Support | 44h |  |
| 29 | 5.4.6 | GN training execution | milestone, manual | 6d | 2021-10-18 | 2021-10-25 |  |  |  | Peter Michaud - Project Manager; Janice Harvey - Project Coordinator | 16h |  |
| 30 | 5.4.7 | GS training execution | milestone, manual | 12d | 2021-11-15 | 2021-11-30 |  |  |  | Peter Michaud - Project Manager; Janice Harvey - Project Coordinator; Manuel Paredes - PIO Support | 19h |  |

| ID | WBS | Task | Type | Duration | Start | Finish | Total slack | Constraint | Resources | Work |
| --- | --- | --- | --- | --- | --- | --- | --- | --- | --- | --- |
| 31 | 5.5 | **MMA/TDA Planetarium Programming** |  | 590d | 2019-07-01 | 2021-10-01 | 0d |  |  | 943.25h |
| 32 | 5.5.1 | Research potential production partners and contractors | manual | 175d | 2019-07-01 | 2020-02-28 |  |  | Peter Michaud - Project Manager; Manuel Paredes - PIO Support | 57h |
| 33 | 5.5.2 | Develop scope of work and program content outlines | manual | 42d | 2020-02-03 | 2020-03-31 |  |  | Peter Michaud - Project Manager; Manuel Paredes - PIO Support | 73.75h |
| 34 | 5.5.3 | Call for proposals/bids for production contract | milestone, manual | 45d | 2020-04-06 | 2020-06-05 |  |  | Peter Michaud - Project Manager; Manuel Paredes - PIO Support | 28h |
| 35 | 5.5.4 | Contractor selection and confirmation | milestone, manual | 15d | 2020-06-08 | 2020-06-26 |  |  | Peter Michaud - Project Manager; Manuel Paredes - PIO Support | 23.5h |
| 36 | 5.5.5 | Planetarium Storyboard collaboration and Program definition | manual | 280d | 2020-07-06 | 2021-07-30 |  |  | Peter Michaud - Project Manager; Manuel Paredes - PIO Support | 570h |
| 37 | 5.5.6 | Acceptance of final segments | manual | 25d | 2021-08-02 | 2021-09-03 |  |  | Peter Michaud - Project Manager; Manuel Paredes - PIO Support | 107h |
| 38 | 5.5.7 | Adaption of Web version of segments | milestone, manual | 20d | 2021-09-06 | 2021-10-01 |  |  | Peter Michaud - Project Manager; Manuel Paredes - PIO Support | 39h |
| 39 | 5.5.8 | Promotion of materials to planetarium community | manual | 20d | 2021-09-06 | 2021-10-01 |  |  | Peter Michaud - Project Manager; Manuel Paredes - PIO Support | 45h |
| 40 | 5.6 | **MMA/TDA Internships** |  | 761d | 2019-01-01 | 2021-11-30 | 0d |  |  | 4796.24h |
| 41 | 5.6.1 | Initiate necessary HR paperwork for MMA-TDA internships | milestone, manual | 94d | 2019-01-01 | 2019-05-10 |  |  | Peter Michaud - Project Manager; Janice Harvey - Project Coordinator | 15h |
| 42 | 5.6.2 | **Intern #1 hired and internship execution** |  | 208d | 2019-05-15 | 2020-02-28 |  |  |  | 1189.24h |
| 43 | 5.6.2.1 | Intern #1 recruitment process | milestone, manual | 78d | 2019-05-15 | 2019-08-30 |  |  | Peter Michaud - Project Manager; Janice Harvey - Project Coordinator | 32h |
| 44 | 5.6.2.2 | Internship #1 orientation | manual | 22d | 2019-09-02 | 2019-10-01 |  |  | Peter Michaud - Project Manager; Janice Harvey - Project Coordinator; Joy Pollard - PIO Support; Intern #1 | 192h |
| 45 | 5.6.2.3 | Internship #1 management and mentoring | manual | 130d | 2019-09-02 | 2020-02-28 |  |  | Peter Michaud - Project Manager; Janice Harvey - Project Coordinator; Joy Pollard - PIO Support; Intern #1 | 866.24h |
| 46 | 5.6.2.4 | Internship #1 completion | manual | 20d | 2020-02-03 | 2020-02-28 |  | start no earlier than 2020-02-03 | Peter Michaud - Project Manager; Janice Harvey - Project Coordinator; Joy Pollard - PIO Support; Intern #1 | 99h |
| 47 | 5.6.3 | **Intern #2 hired and internship execution** |  | 231d | 2019-11-13 | 2020-09-30 |  |  |  | 1212h |
| 48 | 5.6.3.1 | Intern #2 recruitment process | milestone, manual | 78d | 2019-11-13 | 2020-02-28 |  |  | Peter Michaud - Project Manager; Janice Harvey - Project Coordinator | 30h |
| 49 | 5.6.3.2 | Internship #2 orientation | manual | 22d | 2020-03-02 | 2020-03-31 |  |  | Peter Michaud - Project Manager; Janice Harvey - Project Coordinator; Alyssa Grace - PIO Support; Intern #2 | 213h |
| 50 | 5.6.3.3 | Internship #2 management and mentoring | manual | 153d | 2020-03-02 | 2020-09-30 |  |  | Peter Michaud - Project Manager; Janice Harvey - Project Coordinator; Alyssa Grace - PIO Support; Intern #2 | 870h |
| 51 | 5.6.3.4 | Internship #2 completion | manual | 20d | 2020-09-03 | 2020-09-30 |  |  | Peter Michaud - Project Manager; Janice Harvey - Project Coordinator; Alyssa Grace - PIO Support; Intern #2 | 99h |
| 52 | 5.6.4 | **Intern #3 hired and internship execution** |  | 228d | 2020-06-17 | 2021-04-30 |  |  |  | 1189h |
| 53 | 5.6.4.1 | Intern #3 recruitment process | milestone, manual | 78d | 2020-06-17 | 2020-10-02 |  |  | Peter Michaud - Project Manager; Janice Harvey - Project Coordinator | 33h |
| 54 | 5.6.4.2 | Internship #3 orientation | manual | 22d | 2020-10-05 | 2020-11-03 |  |  | Peter Michaud - Project Manager; Janice Harvey - Project Coordinator; Intern #3 | 189h |
| 55 | 5.6.4.3 | Internship #3 management and mentoring | manual | 150d | 2020-10-05 | 2021-04-30 |  |  | Peter Michaud - Project Manager; Janice Harvey - Project Coordinator; Intern #3 | 868h |
| 56 | 5.6.4.4 | Internship #3 completion | manual | 20d | 2021-04-05 | 2021-04-30 |  |  | Peter Michaud - Project Manager; Janice Harvey - Project Coordinator; Intern #3 | 99h |

| ID | WBS | Task | Type | Duration | Start | Finish | Resources | Work |
| --- | --- | --- | --- | --- | --- | --- | --- | --- |
| 57 | 5.6.5 | **Intern #4 hired and internship execution** |  | 230d | 2021-01-13 | 2021-11-30 |  | 1191h |
| 58 | 5.6.5.1 | Intern #4 recruitment process | milestone, manual | 78d | 2021-01-13 | 2021-04-30 | Peter Michaud - Project Manager; Janice Harvey - Project Coordinator | 32h |
| 59 | 5.6.5.2 | Internship #4 orientation | manual | 21d | 2021-05-03 | 2021-05-31 | Peter Michaud - Project Manager; Janice Harvey - Project Coordinator; Alyssa Grace - PIO Support; Intern #4 | 189h |
| 60 | 5.6.5.3 | Internship #4 management and mentoring | manual | 152d | 2021-05-03 | 2021-11-30 | Peter Michaud - Project Manager; Janice Harvey - Project Coordinator; Alyssa Grace - PIO Support; Intern #4 | 871h |
| 61 | 5.6.5.4 | Internship #4 completion | manual | 22d | 2021-11-01 | 2021-11-30 | Peter Michaud - Project Manager; Janice Harvey - Project Coordinator; Alyssa Grace - PIO Support; Intern #4 | 99h |
