# Program MS Project file

Schedule from MS Project, 2018-10-01 to 2024-12-31, costs in $, A marks actual dates.
Gemini Observatory

## Calendars

- Standard: Mon-Fri 08:00-12:00, 13:00-17:00; Sat-Sun off.

## Resources

| Resource | Rate |
| --- | --- |
| Program_Manager | 110 |
| Program_Support_1 | 46 |
| Program_Support_2 | 46 |
| Program_Support_3 | 46 |
| Program_Support_4 | 46 |
| Admin_1 | 43 |
| Program_Support_5 | 46 |

## Schedule

| ID | WBS | Task | Type | Duration | Start | Finish | Predecessors | Complete | Remaining | Total slack | Resources | Work | Actual work | Cost | Actual cost |
| --- | --- | --- | --- | --- | --- | --- | --- | --- | --- | --- | --- | --- | --- | --- | --- |
| 1 | 1 | **Gemini in the Era of Multi-Messenger Astronomy** |  | 1632d | 2018-10-01 A | 2024-12-31 |  |  | 1626.87d | 0d |  | 23567.7h | 31.3h | 1,532,199.76 | 3,443 |
| 2 | 1.1 | **GEMMA program** |  | 1632d | 2018-10-01 A | 2024-12-31 |  |  | 1626.87d | 0d |  | 23567.7h | 31.3h | 1,532,199.76 | 3,443 |
| 3 | 1.1.1 | **Strategic Alignment** |  | 261d | 2018-10-01 | 2019-09-30 |  |  |  | 0d |  | 1096.8h |  | 71,598.4 |  |
| 4 | 1.1.1.1 | Benefits Identification | manual | 43d | 2019-08-01 | 2019-09-30 | 5, 6 |  |  |  | Program_Manager [20%]; Program_Support_1 [10%]; Program_Support_2 [10%] | 137.6h |  | 10,732.8 |  |
| 5 | 1.1.1.2 | Program Benefits | manual | 218d | 2018-10-01 | 2019-07-31 |  |  |  |  | Program_Manager [10%]; Program_Support_1 [10%]; Program_Support_2 [10%] | 523.2h |  | 35,228.8 |  |
| 6 | 1.1.1.3 | Project Benefits | manual | 218d | 2018-10-01 | 2019-07-31 |  |  |  |  | Program_Manager [5%]; Program_Support_1 [10%]; Program_Support_2 [10%] | 436h |  | 25,636.8 |  |
| 7 | 1.1.2 | **Program Structure** |  | 261d | 2018-10-01 A | 2019-09-30 |  | 3% | 252.66d | 0d |  | 958.96h | 31.3h | 83,838 | 3,443 |
| 8 | 1.1.2.1 | Program Schedule | manual | 66d | 2018-10-01 | 2018-12-31 |  |  |  |  | Program_Manager [1%] | 5.28h |  | 580.8 |  |
| 9 | 1.1.2.2 | Program Resource Plan | manual | 26d | 2018-11-26 | 2018-12-31 |  |  |  |  | Program_Manager [1%] | 2.08h |  | 228.8 |  |
| 10 | 1.1.2.3 | **Governance Planning** |  | 195d | 2018-10-01 | 2019-06-28 |  |  |  | 0d |  | 262h |  | 22,930.8 |  |
| 11 | 1.1.2.3.1 | Program Tolerances | manual | 109d | 2019-01-01 | 2019-05-31 |  |  |  |  | Program_Manager [5%]; Admin_1 [5%] | 87.2h |  | 6,670.8 |  |
| 12 | 1.1.2.3.2 | Stakeholder Identification | manual | 175d | 2018-10-01 | 2019-05-31 |  |  |  |  | Program_Manager [5%] | 70h |  | 7,700 |  |
| 13 | 1.1.2.3.3 | Roles and Responsibilities | manual | 87d | 2019-01-01 | 2019-05-01 |  |  |  |  | Program_Manager [5%]; Program_Support_1 [5%] | 69.6h |  | 5,428.8 |  |
| 14 | 1.1.2.3.4 | Communication Strategy | manual | 20d | 2019-06-03 | 2019-06-28 | 13, 12 |  |  |  | Program_Manager [15%]; Program_Support_4 [2%]; Admin_1 [5%] | 35.2h |  | 3,131.2 |  |
| 15 | 1.1.2.4 | **Risk Management Planning** |  | 175d | 2018-10-01 A | 2019-05-31 |  | 18% | 143.96d | 0d |  | 122.8h | 31.3h | 11,739.2 | 3,443 |
| 16 | 1.1.2.4.1 | Initial Risk Identification and Assessment | manual | 92.88d | 2018-10-01 A | 2019-02-06 |  | 39% | 57.07d |  | Program_Manager [10%]; Admin_1 [5%] | 79.2h | 31.3h | 6,943.2 | 3,443 |
| 17 | 1.1.2.4.2 | Risk Management Plan | manual | 109d | 2019-01-01 | 2019-05-31 | 16 |  |  |  | Program_Manager [5%] | 43.6h |  | 4,796 |  |
| 18 | 1.1.2.5 | **Program Deliverables** |  | 261d | 2018-10-01 | 2019-09-30 |  |  |  | 0d |  | 523.2h |  | 43,562.4 |  |
| 19 | 1.1.2.5.1 | Identify deliverables | manual | 66d | 2018-10-01 | 2018-12-31 |  |  |  |  | Program_Manager [20%] | 105.6h |  | 11,616 |  |
| 20 | 1.1.2.5.2 | Deliverables development | manual | 261d | 2018-10-01 | 2019-09-30 |  |  |  |  | Program_Manager [10%]; Admin_1 [10%] | 417.6h |  | 31,946.4 |  |
| 21 | 1.1.2.6 | **Change Management Planning** |  | 109d | 2019-01-01 | 2019-05-31 |  |  |  | 0d |  | 43.6h |  | 4,796 |  |
| 22 | 1.1.2.6.1 | Change Management Plan | manual | 109d | 2019-01-01 | 2019-05-31 |  |  |  |  | Program_Manager [5%] | 43.6h |  | 4,796 |  |
| 23 | 1.1.3 | **Program Management and Administration** |  | 1566d | 2018-10-01 | 2024-09-30 |  |  |  | 0d |  | 19831h |  | 1,254,653.28 |  |
| 24 | 1.1.3.1 | Program and Projects Scope Monitoring and Control | manual | 1500d | 2019-01-01 | 2024-09-30 |  |  |  |  | Program_Manager [2%]; Admin_1 [10%] | 1440h |  | 78,000 |  |
| 25 | 1.1.3.2 | Program and Projects Schedule Monitoring and Control | manual | 1500d | 2019-01-01 | 2024-09-30 |  |  |  |  | Program_Manager [2%]; Admin_1 [10%] | 1440h |  | 78,000 |  |
| 26 | 1.1.3.3 | Program and Projects Resource Monitoring and Control | manual | 1500d | 2019-01-01 | 2024-09-30 |  |  |  |  | Program_Manager [4%]; Program_Support_3 [1%]; Admin_1 [10%] | 1779.12h |  | 108,959.52 |  |
| 27 | 1.1.3.4 | Program and Projects Financial Monitoring and Control | manual | 1500d | 2019-01-01 | 2024-09-30 |  |  |  |  | Program_Manager [10%]; Admin_1 [10%] | 2400h |  | 183,600 |  |
| 28 | 1.1.3.5 | Program and Projects Procurement Monitoring and Control | manual | 1566d | 2018-10-01 | 2024-09-30 |  |  |  |  | Program_Manager [10%]; Admin_1 [10%]; Program_Support_5 [50%] | 8769.6h |  | 479,822.4 |  |
| 29 | 1.1.3.6 | Program and Projects Risk Monitoring and Control | manual | 1500d | 2019-01-01 | 2024-09-30 |  |  |  |  | Program_Manager [15%]; Admin_1 [10%] | 3000h |  | 249,600 |  |
| 30 | 1.1.3.7 | Program and Projects Change Monitoring and Control | manual | 1566d | 2018-10-01 | 2024-09-30 |  |  |  |  | Program_Manager [4%]; Admin_1 [4%] | 1002.24h |  | 76,671.36 |  |

Notes:
- 4: Initial definition is to ensure the delivery of the identified benefits and their value
- 5: Using the information provided by individual projects, regarding their benefits, identify program support structure that links benefits of those projects to each other, and ensure agreement with the Observatory goals
- 6: WBS Dictionary: / Gather GEMMA projects' business cases, justifications, and mandates, to understand the reason for the each individual project and the value they bring to Operations
- 11: WBS Dictionary: / Identify program tolerances
- 12: WBS Dictionary: / Identifying and analyzing the stakeholders to create a registry that identifies stakeholder needs and potential impact on issues and informs the distribution of reports and other communcations.
- 13: WBS Dictionary: / Identify program roles and responsibilites
- 14: WBS Dictionary: / Identify methods to engage stakeholders based on the stakeholder analysis.
- 16: WBS Dictionary: / Identifying and assessing risks include a review of project documentation, interviews with project team members, the creation and updating of the risk register, and presentation of results.
- 17: WBS Dictionary: / Define how risks will be handled for the duration of the program

| ID | WBS | Task | Type | Duration | Start | Finish | Complete | Remaining | Actual start | Total slack | Resources | Work | Cost |
| --- | --- | --- | --- | --- | --- | --- | --- | --- | --- | --- | --- | --- | --- |
| 31 | 1.1.4 | **Program Closure** |  | 66d | 2024-07-01 | 2024-09-30 |  |  |  | 0d |  | 177.6h | 13,617.6 |
| 32 | 1.1.4.1 | Financial Closure | manual | 66d | 2024-07-01 | 2024-09-30 |  |  |  |  | Program_Manager [5%]; Admin_1 [5%] | 52.8h | 4,039.2 |
| 33 | 1.1.4.2 | Procurement Closure | manual | 65d | 2024-07-01 | 2024-09-27 |  |  |  |  | Program_Manager [5%]; Admin_1 [5%] | 52h | 3,978 |
| 34 | 1.1.4.3 | Resource Transition | manual | 65d | 2024-07-01 | 2024-09-27 |  |  |  |  | Program_Manager [2%]; Program_Support_3 [2%] | 20.8h | 1,622.4 |
| 35 | 1.1.4.4 | Risk Management Transition | manual | 65d | 2024-07-01 | 2024-09-27 |  |  |  |  | Program_Manager [5%]; Admin_1 [5%] | 52h | 3,978 |
| 36 | 1.1.5 | **Reviews and Meetings** |  | 1632d | 2018-10-01 | 2024-12-31 | 21% | 1296d | 2019-01-01 | 0d |  | 1503.36h | 108,492.48 |
| 37 | 1.1.5.1 | **NSF Reviews and Audits** |  | 1566d | 2018-10-01 | 2024-09-30 | 21% | 1243.59d | 2019-01-01 |  | Program_Manager [5%]; Admin_1 [2%]; Program_Support_3 [5%] | 1503.36h | 108,492.48 |
| 38 | 1.1.5.1.1 | Program Execution Plan Submission | milestone, manual | 1d | 2019-01-01 A | 2019-01-01 A | 100% |  |  |  |  |  |  |
| 39 | 1.1.5.1.2 | 2019A Report to NSF | milestone, manual | 1d | 2019-05-15 A | 2019-05-15 A | 100% |  |  |  |  |  |  |
| 40 | 1.1.5.1.3 | TDA and PIO Delta-PEP Submission | milestone, manual | 1d | 2019-05-08 A | 2019-05-08 A | 100% |  |  |  |  |  |  |
| 41 | 1.1.5.1.4 | Program and GNAO/RTC Delta-PEP submisison | milestone, manual | 1d | 2019-05-24 A | 2019-05-24 | 50% | 0.5d |  |  |  |  |  |
| 42 | 1.1.5.1.5 | 2019B Report to NSF | milestone, manual | 1d | 2019-11-15 | 2019-11-15 |  |  |  |  |  |  |  |
| 43 | 1.1.5.1.6 | First Annual Review | milestone, manual | 1d | 2019-09-30 | 2019-09-30 |  |  |  |  |  |  |  |
| 44 | 1.1.5.1.7 | 2020A Report to NSF | milestone, manual | 1d | 2020-05-15 | 2020-05-15 |  |  |  |  |  |  |  |
| 45 | 1.1.5.1.8 | 2020B Report to NSF | milestone, manual | 1d | 2020-11-13 | 2020-11-13 |  |  |  |  |  |  |  |
| 46 | 1.1.5.1.9 | 2021A Report to NSF | milestone, manual | 1d | 2021-05-14 | 2021-05-14 |  |  |  |  |  |  |  |
| 47 | 1.1.5.1.10 | 2021B Report to NSF | milestone, manual | 1d | 2021-11-15 | 2021-11-15 |  |  |  |  |  |  |  |
| 48 | 1.1.5.1.11 | 2022A Report to NSF | milestone, manual | 1d | 2022-05-13 | 2022-05-13 |  |  |  |  |  |  |  |
| 49 | 1.1.5.1.12 | 2022B Report to NSF | milestone, manual | 1d | 2022-11-15 | 2022-11-15 |  |  |  |  |  |  |  |
| 50 | 1.1.5.1.13 | 2023A Report to NSF | milestone, manual | 1d | 2023-05-15 | 2023-05-15 |  |  |  |  |  |  |  |
| 51 | 1.1.5.1.14 | 2023B Report to NSF | milestone, manual | 1d | 2023-11-15 | 2023-11-15 |  |  |  |  |  |  |  |
| 52 | 1.1.5.1.15 | 2024A Report to NSF | milestone, manual | 1d | 2024-05-15 | 2024-05-15 |  |  |  |  |  |  |  |
| 53 | 1.1.5.1.16 | 2024B Report to NSF | milestone, manual | 1d | 2024-11-15 | 2024-11-15 |  |  |  |  |  |  |  |
| 54 | 1.1.5.1.17 | Program Closure Report | milestone, manual | 1d | 2024-12-31 | 2024-12-31 |  |  |  |  |  |  |  |
