# Time Domain Software Plan

Schedule from MS Project, 2018-11-19 to 2022-06-10, costs in $, A marks actual dates.

## Calendars

- Standard: Mon-Fri 08:00-12:00, 13:00-17:00; Sat-Sun off.

## Resources

| Resource | Rate |
| --- | --- |
| High Level Software Architect | 80.15 |
| High Level Software Developer | 80.15 |
| Scientific Programmer | 80.15 |
| Project Scientist | 80.86 |
| Data Reduction Software Lead | 80.15 |
| Queue Coordinator | 80.86 |
| Obsever | 80.86 |
| Senior Supplier Data Reduction | 126.2 |
| Senior Supplier Data Product Management | 126.2 |
| Project Manager | 126.2 |
| Project Sponsor | 126.2 |
| System Engineer | 92.21 |

## Schedule

| ID | WBS | Task | Duration | Start | Finish | Predecessors | Complete | Remaining | Total slack | Free slack | Constraint | Resources | Work | Actual work | Cost |
| --- | --- | --- | --- | --- | --- | --- | --- | --- | --- | --- | --- | --- | --- | --- | --- |
| 1 | 1.4.1 | Operational Concept Definition | 24.6w | 2018-11-26 A | 2019-05-15 |  | 90% | 2.46w | 0d |  | must finish on 2019-05-15 | Project Manager [1%]; Project Scientist [5.1%]; Project Sponsor [2%]; Senior Supplier Data Reduction [2%]; High Level Software Architect [2%]; Senior Supplier Data Product Management [1%]; System Engineer [2%] | 150h | 135h | 15,062.2 |
| 2 | 1.4.2 | **Scheduler** | 4650h | 2019-05-16 | 2021-08-06 | 1 |  |  | 220.75d | 0d |  |  | 8374h |  | 673,602.08 |
| 3 | 1.4.2.1 | **Requirements and initial prototype** | 1.06mo | 2019-05-16 | 2019-06-14 |  |  |  | 220.75d | 0d |  |  | 510h |  | 41,238.6 |
| 4 | 1.4.2.1.1 | Develop Weighting Scheme | 170h | 2019-05-16 | 2019-06-14 |  |  |  | 220.75d |  | start no earlier than 2018-11-18 | Project Scientist; Queue Coordinator | 340h |  | 27,492.4 |
| 5 | 1.4.2.1.2 | Constraint Requirements | 170h | 2019-05-16 | 2019-06-14 |  |  |  | 220.75d |  | start no earlier than 2018-11-18 | Project Scientist | 170h |  | 13,746.2 |
| 6 | 1.4.2.2 | Inital Prototype and Architecture definition | 4mo | 2019-06-14 | 2019-10-04 | 3 |  |  | 220.75d | 0d |  | High Level Software Architect; Project Scientist [50%] | 960h |  | 77,171.2 |
| 7 | 1.4.2.3 | Implementation | 9mo | 2019-10-04 | 2020-06-12 | 6 |  |  | 220.75d | 0d |  | High Level Software Architect | 1440h |  | 115,416 |
| 8 | 1.4.2.4 | **OCS Support Infrastructure** | 2400h | 2019-06-14 | 2020-08-07 | 3 |  |  | 300.75d | 0d |  |  | 1664h |  | 133,574.08 |
| 9 | 1.4.2.4.1 | OCS Software Requirements Definition | 3mo | 2019-06-14 | 2019-09-06 |  |  |  | 300.75d | 0d |  | Project Scientist [33.3%]; High Level Software Developer [20%] | 256h |  | 20,632 |
| 10 | 1.4.2.4.2 | **Model support** | 1920h | 2019-09-06 | 2020-08-07 | 9 |  |  | 300.75d |  |  |  | 1408h |  | 112,942.08 |
| 11 | 1.4.2.4.2.1 | Constraints | 240d | 2019-09-06 | 2020-08-07 |  |  |  | 300.75d |  | start no earlier than 2019-01-01 | Project Scientist [3.3%]; High Level Software Developer [33.3%] | 704h |  | 56,471.04 |
| 12 | 1.4.2.4.2.2 | Observation Organization | 240d | 2019-09-06 | 2020-08-07 |  |  |  | 300.75d |  | start no earlier than 2019-01-01 | Project Scientist [3.3%]; High Level Software Developer [33.3%] | 704h |  | 56,471.04 |
| 13 | 1.4.2.5 | Scheduler Testing | 6mo | 2020-06-12 | 2020-11-27 | 7 |  |  | 220.75d | 0d |  | Project Scientist [8.3%]; High Level Software Architect [8.3%]; Queue Coordinator [8.3%]; Obsever [17.7%] | 410h |  | 33,095.8 |
| 14 | 1.4.2.6 | OCS Contingency | 9mo | 2020-11-27 | 2021-08-06 | 8, 13 |  |  | 220.75d |  |  | High Level Software Architect [93.8%]; High Level Software Developer [93.8%]; Project Scientist [27.8%]; Queue Coordinator [9%]; System Engineer [5.6%]; Obsever [5.6%] | 3390h |  | 273,106.4 |
| 15 | 1.4.3 | **TDA APIs** | 1680h | 2019-05-16 | 2020-03-04 | 1 |  |  | 299.5d | 0d | start no earlier than 2018-11-18 |  | 2486h |  | 199,582.34 |
| 16 | 1.4.3.1 | Operational Requirements | 80h | 2019-05-16 | 2019-05-29 |  |  |  | 299.5d | 0d | start no earlier than 2018-11-18 | Project Scientist | 80h |  | 6,468.8 |
| 17 | 1.4.3.2 | TOM APIs Implementation | 4mo | 2019-05-30 | 2019-09-18 | 16 |  |  | 299.5d | 0d |  | High Level Software Architect [90%]; Project Scientist [11.2%]; High Level Software Developer [135.9%] | 1518h |  | 121,718.82 |
| 18 | 1.4.3.3 | Scheduler Interfaces Implementation | 4mo | 2019-09-19 | 2020-01-08 | 17 |  |  | 299.5d | 0d |  | High Level Software Architect [90%]; Project Scientist [11.2%] | 648h |  | 51,988.32 |
| 19 | 1.4.3.4 | API testing | 2mo | 2020-01-09 | 2020-03-04 | 17, 18 |  |  | 299.5d | 0d |  | Project Scientist [25%]; Obsever [25%]; Queue Coordinator [25%] | 240h |  | 19,406.4 |
| 20 | 1.4.4 | **Gemini Plugin for TOM Toolkit** | 1220h | 2020-03-05 | 2020-10-05 | 15 |  |  | 299.5d | 0d | start no earlier than 2018-11-18 |  | 1240h |  | 99,627.4 |
| 21 | 1.4.4.1 | TOM Plugin and UI Implementation | 900h | 2020-03-05 | 2020-08-10 |  |  |  | 299.5d | 0d |  | High Level Software Developer; Project Scientist | 1000h |  | 80,221 |
| 22 | 1.4.4.2 | TOM Testing | 2mo | 2020-08-10 | 2020-10-05 | 21 |  |  | 299.5d | 0d |  | Project Scientist [25%]; Obsever [25%]; Queue Coordinator [25%] | 240h |  | 19,406.4 |
| 23 | 1.4.5 | **Real Time Pipelines** | 6680h | 2019-04-01 | 2022-06-10 |  |  |  | 0d |  | start no earlier than 2019-01-01 |  | 7308h |  | 585,736.2 |
| 24 | 1.4.5.1 | **Data Reduction Software** | 6680h | 2019-04-01 | 2022-06-10 |  |  |  | 0d |  | start no earlier than 2018-11-18 |  | 6500h |  | 520,975 |
| 25 | 1.4.5.1.1 | Initial steps | 16.4w | 2019-04-08 | 2019-07-30 |  |  |  | 0d |  | must start on 2019-04-08 | Data Reduction Software Lead [20.1%]; Scientific Programmer [20.1%] | 264h |  | 21,159.6 |
| 26 | 1.4.5.1.2 | Quantum efficiency and flatfield | 42.8w | 2019-07-12 | 2020-05-06 |  |  |  | 0d |  | must start on 2019-07-12 | Data Reduction Software Lead [18.9%]; Scientific Programmer [18.9%] | 648h |  | 51,937.2 |
| 27 | 1.4.5.1.3 | Automated Wavelength Calibration | 25.2w | 2019-04-01 | 2019-09-23 |  |  |  | 0d |  | must start on 2019-04-01 | Data Reduction Software Lead [35.7%]; Scientific Programmer [35.7%] | 720h |  | 57,708 |
| 28 | 1.4.5.1.4 | Automated spectrum and sky substraction | 23.6w | 2019-06-25 | 2019-12-05 |  |  |  | 0d |  | must start on 2019-06-25 | Data Reduction Software Lead [36.9%]; Scientific Programmer [36.9%] | 696h |  | 55,784.4 |
| 29 | 1.4.5.1.5 | Automatic Spectrophotometric Flux Calibration | 10.3w | 2020-02-27 | 2020-05-08 | 28 |  |  | 0d |  | must finish on 2020-05-08 | Data Reduction Software Lead; Scientific Programmer | 824h |  | 66,043.6 |
| 30 | 1.4.5.1.6 | Quicklook reduction software integration | 10.8w | 2020-08-03 | 2020-10-15 |  |  |  | 0d |  | must start on 2020-08-03 | Data Reduction Software Lead [42.6%]; Scientific Programmer [42.6%] | 368h |  | 29,495.2 |
| 31 | 1.4.5.1.7 | Optimization for reliable automation | 7.4w | 2020-08-03 | 2020-09-22 |  |  |  | 0d |  | must start on 2020-08-03 | Data Reduction Software Lead [40.5%]; Scientific Programmer [40.5%] | 240h |  | 19,236 |
| 32 | 1.4.5.1.8 | Science Quality Phase Data Reduction Software (goal) | 88.4w | 2020-10-01 | 2022-06-10 |  |  |  | 0d |  | must start on 2020-10-01 | Data Reduction Software Lead [38.7%]; Scientific Programmer [38.7%] | 2740h |  | 219,611 |

| ID | WBS | Task | Type | Duration | Start | Finish | Predecessors | Complete | Remaining | Total slack | Free slack | Constraint | Resources | Work | Cost |
| --- | --- | --- | --- | --- | --- | --- | --- | --- | --- | --- | --- | --- | --- | --- | --- |
| 33 | 1.4.5.2 | **Operations Tools for Automation** |  | 2576h | 2019-04-08 | 2020-06-30 |  |  |  | 0d |  |  |  | 808h | 64,761.2 |
| 34 | 1.4.5.2.1 | Calibration Tool |  | 193d | 2019-10-04 | 2020-06-30 |  |  |  | 0d |  | must start on 2019-10-04 | Data Reduction Software Lead [5.7%]; Scientific Programmer [5.7%] | 176h | 14,106.4 |
| 35 | 1.4.5.2.2 | Quicklook reduction dispatcher |  | 50.4w | 2019-04-08 | 2020-03-24 |  |  |  | 0d |  | must start on 2019-04-08 | Data Reduction Software Lead [6%]; Scientific Programmer [6%] | 240h | 19,236 |
| 36 | 1.4.5.2.3 | Quality Assessment Reduction |  | 20.4w | 2019-07-30 | 2019-12-18 |  |  |  | 0d |  | must start on 2019-07-30 | Data Reduction Software Lead [24%]; Scientific Programmer [24%] | 392h | 31,418.8 |
| 37 | 1.4.6 | **Product Distribution** |  | 1488.67h | 2019-11-15 | 2020-08-03 | 1 |  |  | 0d |  | start no earlier than 2018-11-25 |  | 1028h | 99,002.9 |
| 38 | 1.4.6.1 | Updates to DRAGONS software |  | 4.25w | 2019-11-15 | 2019-12-16 |  |  |  | 0d |  | must start on 2019-11-15 | Scientific Programmer [15.3%]; Senior Supplier Data Product Management [15.3%]; Senior Supplier Data Reduction [15.3%]; Data Reduction Software Lead [15.3%] | 104h | 10,730.2 |
| 39 | 1.4.6.2 | Updates to Fitsstore (archive) software |  | 11w | 2019-12-03 | 2020-02-18 |  |  |  | 0d |  | must start on 2019-12-03 | Scientific Programmer [31.8%]; Senior Supplier Data Product Management [4.5%]; Data Reduction Software Lead [9.1%] | 200h | 16,951 |
| 40 | 1.4.6.3 | Test and deployment |  | 14.27w | 2020-02-18 | 2020-05-27 | 39 |  |  | 0d |  | must start on 2020-02-18 | Data Reduction Software Lead [25.7%]; Senior Supplier Data Product Management [25.7%]; Scientific Programmer [25.7%] | 440h | 42,020 |
| 41 | 1.4.6.5 | Contingency |  | 9.5w | 2020-05-27 | 2020-08-03 | 40 |  |  | 0d |  | must start on 2020-05-27 | Scientific Programmer [37.4%]; Senior Supplier Data Product Management [37.4%] | 284h | 29,301.7 |
| 42 | 1.4.7 | **Integration and commissioning** |  | 1362h | 2020-10-16 | 2021-06-11 |  |  |  | 0d |  |  |  | 2192h | 175,688.8 |
| 43 | 1.4.7.1 | Deployment of Quicklook Mode |  | 14.4w | 2020-10-16 | 2021-01-25 | 33, 37 |  |  | 0d |  | must start on 2020-10-16 | Scientific Programmer [23.6%]; Data Reduction Software Lead [23.6%] | 272h | 21,800.8 |
| 44 | 1.4.7.2 | OCS Integration |  | 7mo | 2020-11-27 | 2021-06-11 | 13, 19, 22, 31, 39 |  |  | 260.75d |  |  | High Level Software Architect [42.9%]; High Level Software Developer [42.9%]; Data Reduction Software Lead [42.9%]; Scientific Programmer [42.9%] | 1920h | 153,888 |
| 45 | 1.4.8 | **Documentation, Training and Ops Handover** |  | 470h | 2020-10-05 | 2020-12-25 | 20 |  |  | 265.75d | 0d | start no earlier than 2018-11-18 |  | 800h | 64,574.4 |
| 46 | 1.4.8.1 | Preparation |  | 160h | 2020-10-05 | 2020-11-02 |  |  |  | 304.5d |  |  | Project Scientist | 160h | 12,937.6 |
| 47 | 1.4.8.2 | QC Training |  | 160h | 2020-11-27 | 2020-12-25 | 13 |  |  | 265.75d |  |  | Project Scientist; Queue Coordinator | 240h | 19,406.4 |
| 48 | 1.4.8.3 | Observer Training |  | 80h | 2020-10-05 | 2020-10-19 | 20 |  |  | 314.5d |  |  | Project Scientist; Queue Coordinator; Obsever | 240h | 19,406.4 |
| 49 | 1.4.8.4 | Data Reduction Training |  | 160h | 2020-10-05 | 2020-11-02 | 33, 37 |  |  | 304.5d |  |  | Data Reduction Software Lead | 160h | 12,824 |
| 50 | 1.4.9 | Project Management and Administration |  | 780d | 2018-11-19 | 2021-11-12 |  |  |  | 150d |  | start no earlier than 2018-11-19 | Project Manager [3.2%]; Project Sponsor [0.8%]; Project Scientist [1.6%]; System Engineer [3.2%]; Data Reduction Software Lead [5.7%] | 862h | 83,084.8 |
| 51 | 1.4.10 | **Milestones** |  | 7200h | 2018-12-31 A | 2022-06-10 |  |  | 7200h | 0d |  | start no earlier than 2018-11-27 |  |  |  |
| 52 | 1.4.10.1 | Project Plan submitted to NSF | milestone | 0d | 2018-12-31 A | 2018-12-31 A |  | 100% |  |  |  | must start on 2018-12-31 |  |  |  |
| 53 | 1.4.10.2 | Concept of Operations Completed | milestone | 0d | 2019-05-15 | 2019-05-15 | 1 |  |  | 702d | 0d |  |  |  |  |
| 54 | 1.4.10.23 | **Scheduler Work Pagage Milestones** |  | 3210h | 2019-05-16 | 2020-11-27 |  |  |  | 400.75d |  | start no earlier than 2019-04-25 |  |  |  |
| 55 | 1.4.10.23.1 | Scheduler Work Started | milestone | 0d | 2019-05-16 | 2019-05-16 | 2SS |  |  | 802d |  | start no earlier than 2019-04-25 |  |  |  |
| 56 | 1.4.10.23.2 | Requirements and Initial Prototype | milestone | 0d | 2019-06-14 | 2019-06-14 | 3 |  |  | 780.75d |  |  |  |  |  |
| 57 | 1.4.10.23.3 | Final Architecture Definition | milestone | 0d | 2019-10-04 | 2019-10-04 | 6 |  |  | 700.75d |  |  |  |  |  |
| 58 | 1.4.10.23.4 | OCS Support Infrastructure completed | milestone | 0d | 2020-08-07 | 2020-08-07 | 8 |  |  | 480.75d |  |  |  |  |  |
| 59 | 1.4.10.23.5 | Scheduler Implementation completed | milestone | 0d | 2020-06-12 | 2020-06-12 | 7 |  |  | 520.75d |  |  |  |  |  |
| 60 | 1.4.10.23.7 | Gemini Scheduler ready | milestone | 0d | 2020-11-27 | 2020-11-27 | 13 |  |  | 400.75d |  |  |  |  |  |

| ID | WBS | Task | Type | Duration | Start | Finish | Predecessors | Complete | Remaining | Total slack | Free slack | Constraint |
| --- | --- | --- | --- | --- | --- | --- | --- | --- | --- | --- | --- | --- |
| 61 | 1.4.10.24 | **Gemini TDA APIs Work Package Milestones** |  | 1680h | 2019-05-16 | 2020-03-04 |  |  |  | 592d |  | start no earlier than 2019-04-25 |
| 62 | 1.4.10.24.1 | TDA APIs Work Started | milestone | 0d | 2019-05-16 | 2019-05-16 | 15SS |  |  | 802d |  | start no earlier than 2019-04-25 |
| 63 | 1.4.10.24.2 | Operational Requirements Baselined | milestone | 0d | 2019-05-29 | 2019-05-29 | 16 |  |  | 792d |  |  |
| 64 | 1.4.10.24.3 | TOM Interface implementation completed | milestone | 0d | 2019-09-18 | 2019-09-18 | 17 |  |  | 712d |  |  |
| 65 | 1.4.10.24.4 | Scheduler Interfaces Implementation completed | milestone | 0d | 2020-01-08 | 2020-01-08 | 18 |  |  | 632d |  |  |
| 66 | 1.4.10.24.6 | Gemini TDA APIs tested and verified | milestone | 0d | 2020-03-04 | 2020-03-04 | 19 |  |  | 592d |  |  |
| 67 | 1.4.10.3 | **Interface Control Documents** |  | 712h | 2019-05-29 | 2019-10-01 |  |  |  | 89d | 0d |  |
| 68 | 1.4.10.3.1 | Pipeline Interfaces defined | milestone | 0d | 2019-10-01 | 2019-10-01 |  |  |  | 0d |  | must start on 2019-10-01 |
| 69 | 1.4.10.3.3 | Gemini APIs for TDA baselined | milestone | 0d | 2019-05-29 | 2019-05-29 | 16 |  |  | 732d |  |  |
| 70 | 1.4.10.3.4 | Scheduler Interfaces defined | milestone | 0d | 2019-06-14 | 2019-06-14 | 3 |  |  | 720.75d |  |  |
| 71 | 1.4.10.26 | **Product Distribution Work Package Milestones** |  | 1488.67h | 2019-11-15 | 2020-08-03 |  |  |  | 484.92d |  | start no earlier than 2019-04-25 |
| 72 | 1.4.10.26.1 | Product Distribution Work started | milestone | 0d | 2019-11-15 | 2019-11-15 | 37SS |  |  | 671d |  | start no earlier than 2019-04-25 |
| 73 | 1.4.10.26.2 | Updates to DRAGONS software completed | milestone | 0d | 2019-12-16 | 2019-12-16 | 38 |  |  | 649.75d |  |  |
| 74 | 1.4.10.26.3 | Updates to Gemini Archive Completed | milestone | 0d | 2020-02-18 | 2020-02-18 | 39 |  |  | 603.75d |  |  |
| 75 | 1.4.10.26.4 | Product Distribution Work ready | milestone | 0d | 2020-08-03 | 2020-08-03 | 41 |  |  | 484.92d |  |  |
| 76 | 1.4.10.25 | **Gemini Plugin for TOM Milestones** |  | 1220h | 2020-03-05 | 2020-10-05 |  |  |  | 439.5d |  | start no earlier than 2019-04-25 |
| 77 | 1.4.10.25.1 | Gemini Plugin for TOM Started | milestone | 0d | 2020-03-05 | 2020-03-05 | 20SS |  |  | 592d |  | start no earlier than 2019-04-25 |
| 78 | 1.4.10.25.2 | TOM plugin and user inteface implemented | milestone | 0d | 2020-08-10 | 2020-08-10 | 21 |  |  | 479.5d |  |  |
| 79 | 1.4.10.25.4 | Gemini Plugin for TOM completed | milestone | 0d | 2020-10-05 | 2020-10-05 | 22 |  |  | 439.5d |  |  |
| 80 | 1.4.10.27 | **Real Time Pipelines Work Package Milestones** |  | 6680h | 2019-04-01 A | 2022-06-10 |  |  | 6680h | 0d |  |  |
| 81 | 1.4.10.27.1 | Real Time Pipelines Work started | milestone | 0d | 2019-04-01 A | 2019-04-01 A | 23SS | 100% |  |  |  | must start on 2019-04-01 |
| 82 | 1.4.10.27.2 | Operational modifications to support automation completed | milestone | 0d | 2020-06-30 | 2020-06-30 | 33 |  |  | 508d |  | start no earlier than 2019-04-25 |
| 83 | 1.4.10.27.3 | GMOS Long Slit Spectroscopy data reduction implemented | milestone | 0d | 2022-06-10 | 2022-06-10 | 24 |  |  | 0d |  | start no earlier than 2019-04-25 |
| 84 | 1.4.10.27.4 | Deployment of Quicklook mode | milestone | 0d | 2021-01-25 | 2021-01-25 | 43 |  |  | 359d |  | start no earlier than 2019-04-25 |

| ID | WBS | Task | Type | Duration | Start | Finish | Predecessors | Total slack | Free slack | Constraint |
| --- | --- | --- | --- | --- | --- | --- | --- | --- | --- | --- |
| 85 | 1.4.10.28 | **Reviews** |  | 6096h | 2019-07-10 | 2022-06-10 |  | 0d |  | start no earlier than 2019-04-25 |
| 86 | 1.4.10.28.1 | Conceptual Review | milestone | 0d | 2019-07-10 | 2019-07-10 | 53FS+2mo | 702d | 0d | start no earlier than 2018-12-18 |
| 87 | 1.4.10.28.2 | Progress Design Review | milestone | 0d | 2019-10-02 | 2019-10-02 | 86FS+3mo | 702d | 59d | start no earlier than 2018-12-18 |
| 88 | 1.4.10.28.3 | Critical Design Review | milestone | 0d | 2019-12-24 | 2019-12-24 | 67FS+3mo, 87 | 643d |  |  |
| 89 | 1.4.10.28.4 | Integration Preparedness Review | milestone | 0d | 2022-06-10 | 2022-06-10 | 13, 19, 22, 24, 39 | 0d |  |  |
| 90 | 1.4.10.28.5 | Project closure Review | milestone | 0d | 2021-12-31 | 2021-12-31 | 45 | 0d |  | must start on 2021-12-31 |
| 91 | 1.4.10.12 | Training Completed | milestone | 0d | 2020-12-25 | 2020-12-25 | 45 | 380.75d |  |  |
| 92 | 1.4.10.13 | Integration completed | milestone | 0d | 2021-06-11 | 2021-06-11 | 42 | 260.75d |  |  |
| 93 | 1.4.10.14 | Handover to operations | milestone | 0d | 2021-06-11 | 2021-06-11 | 42, 45 | 260.75d |  |  |
